# Enter Project

Schedule from MS Project, 2025-06-02 to 2026-11-17, 7.5 hours a day.

## Calendars

- Standard: Mon-Fri 08:00-12:00, 13:00-16:30; Sat-Sun off. Exceptions (off unless hours are given): 2021-01-01 to 2040-01-01 (New Year's Day, recurring), 2022-01-17 to 2041-01-21 (MLK Day, recurring), 2022-02-21 to 2041-02-18 (Presidents Day, recurring), 2022-05-30 to 2041-05-27 (Memorial Day, recurring), 2022-07-04 to 2041-07-04 (Independence Day, recurring), 2022-09-05 to 2041-09-02 (Labor Day, recurring), 2022-11-11 to 2041-11-08 (Veterans Day, recurring), 2022-11-24 to 2041-11-28 (Thanksgiving, recurring), 2022-11-25 to 2041-11-22 (Day after Thanksgiving, recurring), 2022-12-24 to 2041-12-24 (Christmas Eve, recurring), 2022-12-25 to 2041-12-25 (Christmas Day, recurring), 2022-12-31 to 2041-12-31 (New Year's Eve, recurring), 2023-06-19 to 2041-06-19 (Juneteenth, recurring), 2026-04-03 (Good Friday (2026)).

## Resources

| Resource |
| --- |
| TDOT Project Manager |
| Engineering Concepts Lead |
| Engineering Concepts Manager |
| Active Transportation Lead |
| Environmental Technical Lead |
| Lead Geotechnical Engineer/Geologist |
| TDOT Geotechnical Engineer |
| Statewide Railroad Coordinator |
| TDOT Structural Division Staff |
| TDOT Hydraulics State or Regional Staff |
| TDOT Traffic Designer |
| TDOT Region Roadway Designer |
| TBD |
| TDOT Utility Office Designee |
| Aerial Geodetics Lead |
| TDOT Geodetics |
| Survey Lead |
| Roadway Design Lead |
| TDOT HQ Technical Coordinator 1 |
| Utility Coordinator |
| NEPA Lead |
| Hydraulic Lead |
| Traffic Design Engineer |
| Railroad Coordinator |
| Pavement Team Lead |
| Regional ROW Appraisal Team Lead |
| ROW Acquisition/Relocation Team Lead |
| Structural Design Lead |
| Environmental Permit Lead |
| Engineering Mitigation Lead |
| Mitigation Designer |
| TDOT HQ ROW Appraisal Manager |
| RTE |
| Quality Assurance |
| Quality Team Lead |
| Regionall Quality Team Lead |
| Regional Quality Team Lead |

## Schedule

| ID | WBS | Task | Duration | Start | Finish | Predecessors | Total slack | Free slack | Constraint | Resources | Work |
| --- | --- | --- | --- | --- | --- | --- | --- | --- | --- | --- | --- |
| 1 | 1 | **STAGE 1- CONTEXT/SCOPING** | 246d? | 2025-06-02 | 2026-05-29 |  | 0d |  |  |  | 10680h |
| 2 | 1.1 | **1PM1 Set Up Project** | 33d | 2025-06-02 | 2025-07-18 |  | 0d |  |  |  | 1207.5h |
| 3 | 1.1.1 | 1.0 Confirm Project Assignment | 1d | 2025-06-02 | 2025-06-02 |  | 0d |  | must start on 2025-06-02 | TDOT Project Manager | 7.5h |
| 4 | 1.1.2 | **2.0 Verify Project Funding, Project Number, PIN, and Task Profile Numbers** | 10d | 2025-06-03 | 2025-06-16 | 3 | 334d |  |  |  | 150h |
| 5 | 1.1.2.1 | - Verify Project Information | 10d | 2025-06-03 | 2025-06-16 | 3 | 334d |  |  | TDOT Project Manager | 75h |
| 6 | 1.1.2.2 | - Request and Obtain Authorization of Funds (PE-N) | 10d | 2025-06-03 | 2025-06-16 | 3 | 334d |  |  | TDOT Project Manager | 75h |
| 7 | 1.1.3 | 3.0 Request Shared Project Folder | 10d | 2025-06-03 | 2025-06-16 | 3 | 334d |  |  | TDOT Project Manager | 75h |
| 8 | 1.1.4 | 4.0 Prepare Draft Project Scope | 20d | 2025-06-03 | 2025-07-01 | 3 | 314d | 0d |  | TDOT Project Manager | 150h |
| 9 | 1.1.5 | 5.0 Prepare Preliminary Schedule | 20d | 2025-06-03 | 2025-07-01 | 3 | 309d | 0d |  | TDOT Project Manager | 150h |
| 10 | 1.1.6 | **6.0 Validate Preliminary Budget** | 20d | 2025-06-03 | 2025-07-01 | 3 | 314d |  |  |  | 300h |
| 11 | 1.1.6.1 | - Validate Preliminary Budget | 20d | 2025-06-03 | 2025-07-01 | 3 | 314d | 0d |  | TDOT Project Manager | 150h |
| 12 | 1.1.6.2 | - Confirm/Coordinate Approval of Project in the STIP/TIP | 20d | 2025-06-03 | 2025-07-01 | 3 | 324d |  |  | TDOT Project Manager | 150h |
| 13 | 1.1.7 | 7.0 Prepare Draft Quality Management Plan | 10d | 2025-06-03 | 2025-06-16 | 3 | 334d |  |  | TDOT Project Manager | 75h |
| 14 | 1.1.8 | 8.0 Prepare Draft Risk Management Plan | 20d | 2025-06-03 | 2025-07-01 | 3 | 324d |  |  | TDOT Project Manager | 150h |
| 15 | 1.1.9 | 9.0 Prepare Draft Project Communication Plan | 5d | 2025-06-03 | 2025-06-09 | 3 | 339d |  |  | TDOT Project Manager | 37.5h |
| 16 | 1.1.10 | 10.0 Prepare Draft Project Commitment Document (PCD) | 10d | 2025-07-02 | 2025-07-16 | 8, 9, 11 | 314d |  |  | TDOT Project Manager | 75h |
| 17 | 1.1.11 | 11.0 Request and Obtain Authorization of Funds (ROW and Utilities Incidentals) | 5d | 2025-07-14 | 2025-07-18 | 8, 58, 74 | 312d |  |  | TDOT Project Manager | 37.5h |
| 18 | 1.2 | **1PM2 Build Project Team** | 40d | 2025-06-03 | 2025-07-30 |  | 0d |  |  |  | 487.5h |
| 19 | 1.2.1 | 1.0 Identify Project Team Resources | 5d | 2025-06-03 | 2025-06-09 | 3 | 30d | 0d |  | TDOT Project Manager | 37.5h |
| 20 | 1.2.2 | 2.0 Build Project Team | 20d | 2025-06-10 | 2025-07-09 | 19 | 30d | 2d |  | TDOT Project Manager | 150h |
| 21 | 1.2.3 | 3.0 Determine Type of Consultant(s) and Contract(s) Required | 5d | 2025-06-03 | 2025-06-09 | 3 | 0d |  |  | TDOT Project Manager | 37.5h |
| 22 | 1.2.4 | 4.0 Obtain Consultant(s) | 35d | 2025-06-10 | 2025-07-30 | 21 | 0d |  |  | TDOT Project Manager | 262.5h |
| 23 | 1.3 | **1EC1 Initiate Concept Evaluations** | 17d | 2025-06-03 | 2025-06-26 |  | 13d |  |  |  | 150h |
| 24 | 1.3.1 | 1.0 Request Safety Data | 5d | 2025-06-03 | 2025-06-09 | 3 | 13d | 0d |  | Engineering Concepts Lead | 37.5h |
| 25 | 1.3.2 | 2.0 Coordinate with Planning Division | 5d | 2025-06-03 | 2025-06-09 | 3 | 359d |  |  | Engineering Concepts Lead | 37.5h |
| 26 | 1.3.3 | 3.0 Request Traffic Data | 5d | 2025-06-03 | 2025-06-09 | 3 | 13d | 0d |  | Engineering Concepts Lead | 37.5h |
| 27 | 1.3.4 | 4.0 Initiate Division Reviews | 5d | 2025-06-20 | 2025-06-26 | 67, 68 | 23d | 0d |  | Engineering Concepts Lead | 37.5h |

Notes:
- 26: Note: This duration may take about 30 to 45 days if traffic counts are needed from the Consultant or Road Inventory Office and the Forecast and Visualization Office under the Planning Division.

| ID | WBS | Task | Type | Duration | Start | Finish | Predecessors | Total slack | Free slack | Resources | Work |
| --- | --- | --- | --- | --- | --- | --- | --- | --- | --- | --- | --- |
| 28 | 1.4 | **1EC2 Develop the Conceptual Layout and Complete Site** |  | 42.87d | 2025-06-02 | 2025-08-01 |  | 25.87d |  |  | 337.5h |
| 29 | 1.4.1 | 1.0 Develop Draft Conceptual Layouts and Estimates for the Site Visit |  | 15d | 2025-06-20 | 2025-07-11 | 67, 68 | 13d | 0d | Engineering Concepts Lead | 112.5h |
| 30 | 1.4.2 | 2.0 Compile Initial Divisional Reviews for Site Visit |  | 5d | 2025-07-14 | 2025-07-18 | 29, 40, 45, 49, 53, 58, 62, 63, 74 | 23d | 5d | Engineering Concepts Lead | 37.5h |
| 31 | 1.4.3 | 3.0 Prepare Site Visit Packet and Participate in Site Visit |  | 5d | 2025-07-28 | 2025-08-01 | 30, 35 | 18d | 0d | Engineering Concepts Lead | 37.5h |
| 32 | 1.4.4 | 4.0 Initiate IAR/SOAR Concept Coordination with FHWA |  | 20d | 2025-06-02 | 2025-07-01 |  | 234.87d | 0d | Engineering Concepts Manager | 150h |
| 33 | 1.5 | **1EC3 Develop and Finalize the Concept Report** |  | 55d | 2025-07-14 | 2025-09-29 |  | 18d |  |  | 375h |
| 34 | 1.5.1 | 1.0 Develop, Compile, and Distribute the Draft Concept Report |  | 15d | 2025-08-04 | 2025-08-22 | 31, 29, 24, 26 | 18d | 0d | Engineering Concepts Lead | 112.5h |
| 35 | 1.5.2 | 2.0 Develop Environmental Technical Study Area (ETSA) |  | 10d | 2025-07-14 | 2025-07-25 | 29 | 18d | 0d | Engineering Concepts Lead | 75h |
| 36 | 1.5.3 | 3.0 Finalize the Conceptual Layout |  | 10d | 2025-08-25 | 2025-09-08 | 34, 35, 29 | 202d | 0d | Engineering Concepts Lead | 75h |
| 37 | 1.5.4 | 4.0 Address Comments and Finalize the Concept Report |  | 10d | 2025-09-09 | 2025-09-22 | 42, 47, 51, 55, 60, 65, 71, 76, 36 | 277d | 0d | Engineering Concepts Lead | 75h |
| 38 | 1.5.5 | 5.0 Request for Concept Report Signature(s) and Distribution |  | 5d | 2025-09-23 | 2025-09-29 | 37 | 282d |  | Engineering Concepts Lead | 37.5h |
| 39 | 1.6 | **1AT1 Conduct Active Transportation Review** |  | 50d | 2025-06-27 | 2025-09-08 |  | 28d |  |  | 232.5h |
| 40 | 1.6.1 | 1.0 Conduct Active Transportation Review |  | 5d | 2025-06-27 | 2025-07-03 | 27 | 28d | 5d | Active Transportation Lead | 37.5h |
| 41 | 1.6.2 | 2.0 Attend Site Visit |  | 1d | 2025-08-04 | 2025-08-04 | 31 | 84d | 0d | Active Transportation Lead | 7.5h |
| 42 | 1.6.3 | 3.0 Review the Concept Report |  | 10d | 2025-08-25 | 2025-09-08 | 34 | 277d | 0d | Active Transportation Lead | 75h |
| 43 | 1.6.4 | 4.0 Develop Considerations & Recommendations |  | 15d | 2025-08-05 | 2025-08-25 | 40, 41 | 84d | 0d | Active Transportation Lead | 112.5h |
| 44 | 1.7 | **1EN1 Conduct Environmental Desktop Review** |  | 50d | 2025-06-27 | 2025-09-08 |  | 28d |  |  | 120h |
| 45 | 1.7.1 | 1.0 Identify Known Environmental Resource Information |  | 5d | 2025-06-27 | 2025-07-03 | 27 | 28d | 5d | Environmental Technical Lead | 37.5h |
| 46 | 1.7.2 | 2.0 Attend Site Visit |  | 1d | 2025-08-04 | 2025-08-04 | 31 | 321d |  | Environmental Technical Lead | 7.5h |
| 47 | 1.7.3 | 3.0 Review the Concept Report |  | 10d | 2025-08-25 | 2025-09-08 | 34 | 277d | 0d | Environmental Technical Lead | 75h |
| 48 | 1.8 | **1GT1 Conduct Preliminary Geotechnical Assessment** |  | 50d | 2025-06-27 | 2025-09-08 |  | 23d |  |  | 150h |
| 49 | 1.8.1 | 1.0 Complete Geotechnical Division Review |  | 10d | 2025-06-27 | 2025-07-11 | 27 | 23d | 0d | TDOT Geotechnical Engineer | 75h |
| 50 | 1.8.2 | 2.0 Attend Site Visit | milestone | 0d | 2025-08-01 | 2025-08-01 | 31 | 322d |  | TDOT Geotechnical Engineer |  |
| 51 | 1.8.3 | 3.0 Review the Concept Report |  | 10d | 2025-08-25 | 2025-09-08 | 34 | 277d | 0d | TDOT Geotechnical Engineer | 75h |

Notes:
- 31: This activity could include the Kickoff Meeting (1PM3)
- 32: If an IAR or SOAR is anticipated, tie up logic accordingly

| ID | WBS | Task | Type | Duration | Start | Finish | Predecessors | Total slack | Free slack | Resources | Work |
| --- | --- | --- | --- | --- | --- | --- | --- | --- | --- | --- | --- |
| 52 | 1.9 | **1RD1 Provide Roadway Desktop Review** |  | 50d | 2025-06-27 | 2025-09-08 |  | 28d |  |  | 187.5h |
| 53 | 1.9.1 | 1.0 Complete Roadway Division Review |  | 5d | 2025-06-27 | 2025-07-03 | 27 | 28d | 5d | TDOT Region Roadway Designer | 37.5h |
| 54 | 1.9.2 | 2.0 Attend Site Visit | milestone | 0d | 2025-08-01 | 2025-08-01 | 31 | 322d |  | TDOT Region Roadway Designer |  |
| 55 | 1.9.3 | 3.0 Review the Concept Report |  | 10d | 2025-08-25 | 2025-09-08 | 34 | 277d | 0d | TDOT Region Roadway Designer | 75h |
| 56 | 1.9.4 | 4.0 Complete the Design Decision Worksheet |  | 10d | 2025-08-25 | 2025-09-08 | 34 | 18d | 0d | TDOT Region Roadway Designer | 75h |
| 57 | 1.10 | **1RR1 Complete Concept-Level Railroad Review** |  | 50d | 2025-06-27 | 2025-09-08 |  | 28d |  |  | 112.5h |
| 58 | 1.10.1 | 1.0 Provide Review for Potential Railroad in the Project Area |  | 5d | 2025-06-27 | 2025-07-03 | 27 | 28d | 5d | Railroad Coordinator | 37.5h |
| 59 | 1.10.2 | 2.0 Attend Site Visit | milestone | 0d | 2025-08-01 | 2025-08-01 | 31 | 322d |  | Railroad Coordinator |  |
| 60 | 1.10.3 | 3.0 Review the Concept Report |  | 10d | 2025-08-25 | 2025-09-08 | 34 | 277d | 0d | Railroad Coordinator | 75h |
| 61 | 1.11 | **1ST1 Develop Structures Recommendations** |  | 50d | 2025-06-27 | 2025-09-08 |  | 23d |  |  | 187.5h |
| 62 | 1.11.1 | 1.0 Recommend Structure Type |  | 5d | 2025-06-27 | 2025-07-03 | 27 | 28d | 5d | TDOT Structural Division Staff | 37.5h |
| 63 | 1.11.2 | 2.0 Provide Hydraulic Recommendations |  | 10d | 2025-06-27 | 2025-07-11 | 27 | 23d | 0d | TDOT Hydraulics State or Regional Staff | 75h |
| 64 | 1.11.3 | 3.0 Attend Site Visit | milestone | 0d | 2025-08-01 | 2025-08-01 | 31 | 322d |  | TDOT Structural Division Staff |  |
| 65 | 1.11.4 | 4.0 Review the Concept Report |  | 10d | 2025-08-25 | 2025-09-08 | 34 | 277d | 0d | TDOT Structural Division Staff | 75h |
| 66 | 1.12 | **1TD1 Initiate Traffic and Safety Analyses** |  | 82d | 2025-06-10 | 2025-10-06 |  | 13d |  |  | 307.5h |
| 67 | 1.12.1 | 1.0 Conduct Initial Safety Analysis |  | 7d | 2025-06-10 | 2025-06-18 | 24 | 13d | 0d | TDOT Traffic Designer | 52.5h |
| 68 | 1.12.2 | 2.0 Conduct Intersection and Interchange Evaluation (IIE) |  | 7d | 2025-06-10 | 2025-06-18 | 26 | 13d | 0d | TDOT Traffic Designer | 52.5h |
| 69 | 1.12.3 | 3.0 Alignment & Operations Review |  | 7d | 2025-07-14 | 2025-07-22 | 29 | 330d |  | TDOT Traffic Designer | 52.5h |
| 70 | 1.12.4 | 4.0 Attend Site Visit | milestone | 0d | 2025-08-01 | 2025-08-01 | 31 | 322d |  | TDOT Traffic Designer |  |
| 71 | 1.12.5 | 5.0 Review the Concept Report |  | 10d | 2025-08-25 | 2025-09-08 | 34 | 277d | 0d | TBD | 75h |
| 72 | 1.12.6 | 6.0 Develop RSA Generated Projects |  | 10d | 2025-09-23 | 2025-10-06 | 37 | 277d |  | TBD | 75h |
| 73 | 1.13 | **1UT1 Complete Concept-Level Utility Review** |  | 50d | 2025-06-27 | 2025-09-08 |  | 23d |  |  | 150h |
| 74 | 1.13.1 | 1.0 Review Project Area for Potential Utilities |  | 10d | 2025-06-27 | 2025-07-11 | 27 | 23d | 0d | TDOT Utility Office Designee | 75h |
| 75 | 1.13.2 | 2.0 Attend Site Visit | milestone | 0d | 2025-08-01 | 2025-08-01 | 31 | 322d |  | TDOT Utility Office Designee |  |
| 76 | 1.13.3 | 3.0 Review the Concept Report |  | 10d | 2025-08-25 | 2025-09-08 | 34 | 277d | 0d | TDOT Utility Office Designee | 75h |

Notes:
- 56: For urban roadway projects only; see Project Scoping Guide

| ID | WBS | Task | Type | Duration | Start | Finish | Predecessors | Total slack | Free slack | Resources | Work |
| --- | --- | --- | --- | --- | --- | --- | --- | --- | --- | --- | --- |
| 77 | 1.14 | **1PM3 Hold Kickoff Meeting** |  | 5d | 2025-07-28 | 2025-08-01 |  | 18d |  |  | 112.5h |
| 78 | 1.14.1 | 1.0 Hold Meeting | milestone | 0d | 2025-07-30 | 2025-07-30 | 20, 22 | 32d | 0d | TDOT Project Manager |  |
| 79 | 1.14.2 | 2.0 Verify the ETSA |  | 5d | 2025-07-28 | 2025-08-01 | 35, 20 | 18d | 0d | TDOT Project Manager; Environmental Technical Lead; TDOT Region Roadway Designer | 112.5h |
| 80 | 1.15 | **1PM4 Conduct Initial Risk Workshop** |  | 205d | 2025-07-30 | 2026-05-29 |  | 119d |  |  | 22.5h |
| 81 | 1.15.1 | 1.0 Hold Meeting (First Risk Workshop) | milestone | 0d | 2025-07-30 | 2025-07-30 | 20, 22 | 324d |  | TDOT Project Manager |  |
| 82 | 1.15.2 | **2.0 Update and Monitor Risk Register** |  | 127d | 2025-11-20 | 2026-05-29 |  | 119d |  |  | 22.5h |
| 83 | 1.15.2.1 | - Risk Update #1 |  | 1d | 2025-11-20 | 2025-11-20 | 139 | 245d |  | TDOT Project Manager | 7.5h |
| 84 | 1.15.2.2 | - Risk Update #2 |  | 1d | 2026-03-17 | 2026-03-17 | 277 | 170d |  | TDOT Project Manager | 7.5h |
| 85 | 1.15.2.3 | - Risk Update #3 |  | 1d | 2026-05-29 | 2026-05-29 | 334 | 119d |  | TDOT Project Manager | 7.5h |
| 86 | 1.16 | **1SY1 Conduct Design-Level Survey** |  | 70.87d? | 2025-06-02 | 2025-09-11 |  | 99.87d |  |  | 382.5h |
| 87 | 1.16.1 | 1.0 Prepare the Ground Control for Aerial Survey |  | 10d | 2025-06-02 | 2025-06-16 |  | 329.87d | 0d | Aerial Geodetics Lead | 75h |
| 88 | 1.16.2 | 2.0 Complete the Aerial Survey |  | 25d | 2025-06-16 | 2025-07-23 | 87 | 329.87d |  | Aerial Geodetics Lead | 187.5h |
| 89 | 1.16.3 | 3.0 Set Control Ground Survey |  | 5d | 2025-07-14 | 2025-07-18 | 20, 29 | 72d | 0d | TDOT Geodetics | 37.5h |
| 90 | 1.16.4 | 4.0 Conduct Survey Public Involvement and Ground Survey |  | 1d? | 2025-07-21 | 2025-07-21 | 89 | 72d | 0d | Survey Lead | 7.5h |
| 91 | 1.16.5 | 5.0 Incorporate SUE Request into Survey |  | 10d | 2025-08-28 | 2025-09-11 | 102SS+20d | 294d |  | Survey Lead | 75h |
| 92 | 1.17 | **1RD2 Initiate Roadway Design** |  | 58d? | 2025-07-31 | 2025-10-21 |  | 45d |  |  | 330h |
| 93 | 1.17.1 | 1.0 Establish Project-Specific Design Criteria |  | 10d | 2025-09-09 | 2025-09-22 | 78, 90FS-20d, 56 | 18d |  | Roadway Design Lead | 75h |
| 94 | 1.17.2 | 2.0 Determine Work Zone Significance |  | 10d | 2025-07-31 | 2025-08-13 | 78, 90FS-20d | 45d |  | Roadway Design Lead | 75h |
| 95 | 1.17.3 | 3.0 Request Driveway Deviations |  | 20d | 2025-08-21 | 2025-09-18 | 96FS-40d | 289d |  | Roadway Design Lead | 150h |
| 96 | 1.17.4 | 4.0 Develop Line, Grade, and Cross Sections (Line and Grade Package) |  | 1d? | 2025-10-16 | 2025-10-16 | 78, 90FS-20d, 110FF+10d, 126FF+15d | 0d |  | Roadway Design Lead | 7.5h |
| 97 | 1.17.5 | 5.0 Compile the Line and Grade Package for Field Review |  | 3d | 2025-10-17 | 2025-10-21 | 96, 93, 94 | 0d |  | Roadway Design Lead | 22.5h |
| 98 | 1.18 | **1EC4 Complete an IAR or SOAR** |  | 170.87d | 2025-07-01 | 2026-03-11 |  | 174d |  |  | 1275h |
| 99 | 1.18.1 | 1.0 Obtain IAR Approval |  | 110d | 2025-09-26 | 2026-03-11 | 32, 126 | 174d |  | Engineering Concepts Manager | 825h |
| 100 | 1.18.2 | 2.0 Obtain SOAR Concurrence |  | 60d | 2025-07-01 | 2025-09-25 | 32 | 284.87d |  | Engineering Concepts Lead | 450h |

Notes:
- 78: Could be combined with the site visit under the EC activities above (tie up logic as needed)
- 81: Could be held with the kickoff meeting (logic assumes that right now; adjust as needed).
- 83: Risk can also be discussed during the respective field review
- 87: Tie up logic to when it is best done seasonally
- 90: To included picking up utilities, property information, and potentially staked ecology features (OHWM, steams, ephemerals, wetlands) amongst other standard survey items.
- 91: Potential early task
- 93: Could start right after the kickoff meeting or after the kickoff meeting and completion of ground survey
- 96: VERIFY LOGIC TIES for this critical path design item. Duration depends on size of the project/complexity of design, and can be run parallel with survey, but team will likely need at least a month to tie in survey.
- 98: If applicable for the project (tie up logic under 1EC2). This will also be one or the other, depending on what level of document was coordinated with FHWA based on the scope of the change.
- 99: Note that the environmental document approval will need to be tied as a successor to the end of this approval (if used).

| ID | WBS | Task | Duration | Start | Finish | Predecessors | Total slack | Free slack | Resources | Work |
| --- | --- | --- | --- | --- | --- | --- | --- | --- | --- | --- |
| 101 | 1.19 | **1UT2 Begin Utility Coordination** | 73d | 2025-07-31 | 2025-11-11 |  | 32d |  |  | 495h |
| 102 | 1.19.1 | 1.0 Make Initial Utility Contact | 50d | 2025-07-31 | 2025-10-09 | 78 | 32d | 0d | TDOT HQ Technical Coordinator 1 | 375h |
| 103 | 1.19.2 | 2.0 Conduct Utility Coordination Kickoff Meeting | 1d | 2025-10-10 | 2025-10-10 | 102 | 32d | 7d | Utility Coordinator | 7.5h |
| 104 | 1.19.3 | 3.0 Prepare a Utility Estimate | 15d | 2025-10-22 | 2025-11-11 | 97 | 216d | 20d | Utility Coordinator | 112.5h |
| 105 | 1.20 | **1EN2 Complete Environmental Resource Identification** | 77d | 2025-08-04 | 2025-11-20 |  | 18d |  |  | 2032.5h |
| 106 | 1.20.1 | 1.0 Identify Historic Property Boundary(ies) and Initiate Agency Coordination | 45d | 2025-08-04 | 2025-10-06 | 79 | 55d | 31d | Environmental Technical Lead | 337.5h |
| 107 | 1.20.2 | 2.0 Identify Boundary(ies) for Potentially Eligible Archaeology Sites and Initiate Agency Coordination | 50d | 2025-08-04 | 2025-10-13 | 79 | 31d | 26d | Environmental Technical Lead | 375h |
| 108 | 1.20.3 | 3.0 Conduct Native American Coordination to Identify Consulting Parties | 15d | 2025-08-04 | 2025-08-22 | 79 | 307d |  | Environmental Technical Lead | 112.5h |
| 109 | 1.20.4 | **4.0 Identify Ecology Site Boundaries** | 40d | 2025-08-04 | 2025-09-29 |  | 18d | 16d |  | 487.5h |
| 110 | 1.20.4.1 | - Develop and send shapefiles of features to design for L&G | 25d | 2025-08-04 | 2025-09-08 | 79 | 18d |  | Environmental Technical Lead | 187.5h |
| 111 | 1.20.4.2 | - Complete an Environmental Boundaries Report (EBR) | 40d | 2025-08-04 | 2025-09-29 | 79 | 46d |  | Environmental Technical Lead | 300h |
| 112 | 1.20.5 | 5.0 Establish Air Quality Designation | 20d | 2025-08-04 | 2025-08-29 | 79 | 61d | 56d | Environmental Technical Lead | 150h |
| 113 | 1.20.6 | 6.0 Identify Potential Noise Receptor Locations | 30d | 2025-08-04 | 2025-09-15 | 79 | 70d | 46d | Environmental Technical Lead | 225h |
| 114 | 1.20.7 | 7.0 Identify Potential Hazardous Materials Sites | 20d | 2025-08-04 | 2025-08-29 | 79 | 80d | 56d | Environmental Technical Lead | 150h |
| 115 | 1.20.8 | 8.0 Identify Section 4(f) and Section 6(f) Resources | 20d | 2025-08-04 | 2025-08-29 | 79 | 302d |  | Environmental Technical Lead | 150h |
| 116 | 1.20.9 | 9.0 Analyze CSRP | 3d | 2025-11-12 | 2025-11-17 | 195 | 245d | 0d | Environmental Technical Lead | 22.5h |
| 117 | 1.20.10 | 10.0 Determine the NEPA Class of Action | 3d | 2025-11-18 | 2025-11-20 | 116 | 245d |  | NEPA Lead | 22.5h |
| 118 | 1.21 | **1GT2 Develop Geotechnical Work Plan** | 60d | 2025-07-22 | 2025-10-14 |  | 50d |  |  | 150h |
| 119 | 1.21.1 | 1.0 Gather Relevant Geotechnical Information | 5d | 2025-07-22 | 2025-07-28 | 90 | 90d | 0d | Lead Geotechnical Engineer/Geologist | 37.5h |
| 120 | 1.21.2 | 2.0 Conduct Initial Field Visit (if needed) | 5d | 2025-07-29 | 2025-08-04 | 119 | 90d | 22d | Lead Geotechnical Engineer/Geologist | 37.5h |
| 121 | 1.21.3 | 3.0 Identify Project Type and Potential Mitigation Strategies | 5d | 2025-09-05 | 2025-09-11 | 120, 96FS-30d | 68d | 18d | Lead Geotechnical Engineer/Geologist | 37.5h |
| 122 | 1.21.4 | 4.0 Develop Geotechnical Work Plan | 5d | 2025-10-08 | 2025-10-14 | 97FS-30d, 121, 185, 232 | 50d | 0d | Lead Geotechnical Engineer/Geologist | 37.5h |
| 123 | 1.22 | **1ST2 Complete Existing and No Structure Modeling** | 20d | 2025-07-31 | 2025-08-27 |  | 304d |  |  | 150h |
| 124 | 1.22.1 | 1.0 Hydraulically Model Existing and No Structure Conditions | 20d | 2025-07-31 | 2025-08-27 | 78, 90 | 304d |  | Hydraulic Lead | 150h |

Notes:
- 102: Includes 60 day initial timeline + 10-day extension (50 working days)
- 110: Recommend the data collection/field survey work for ecology be done ASAP in Stage 1 (while survey is modelized in 1SY1), so that the shapefiles can be incorporated into the Line and Grade Package before finalizing. If the shapefiles are available prior to
- 122: Logic could be simplified depending scope of the geotech work

| ID | WBS | Task | Type | Duration | Start | Finish | Predecessors | Baseline start | Baseline finish | Baseline duration | Total slack | Free slack | Resources | Work | Text1 |
| --- | --- | --- | --- | --- | --- | --- | --- | --- | --- | --- | --- | --- | --- | --- | --- |
| 125 | 1.23 | **1TD2 Conduct Traffic Analysis, Warrants, and Significance Determination** |  | 52d | 2025-07-31 | 2025-10-13 |  |  |  |  | 0d |  |  | 825h |  |
| 126 | 1.23.1 | 1.0 Complete the Traffic Operations Analysis |  | 40d | 2025-07-31 | 2025-09-25 | 22, 29 |  |  |  | 0d |  | Traffic Design Engineer | 300h |  |
| 127 | 1.23.2 | 2.0 Complete the Traffic Safety Evaluation |  | 15d | 2025-07-31 | 2025-08-20 | 22, 29 |  |  |  | 309d |  | Traffic Design Engineer | 112.5h |  |
| 128 | 1.23.3 | 3.0 Analyze Signal Warrants |  | 15d | 2025-09-09 | 2025-09-29 | 36, 22 |  |  |  | 202d | 0d | Traffic Design Engineer | 112.5h |  |
| 129 | 1.23.4 | 4.0 Analyze Lighting Warrants |  | 15d | 2025-09-09 | 2025-09-29 | 36, 22 |  |  |  | 202d | 0d | Traffic Design Engineer | 112.5h |  |
| 130 | 1.23.5 | 5.0 Prepare Signal, Lighting, and ITS Scope and Estimate |  | 10d | 2025-09-30 | 2025-10-13 | 128, 129 |  |  |  | 202d | 26d | Traffic Design Engineer | 75h |  |
| 131 | 1.23.6 | 6.0 Complete Systems Engineering Analysis |  | 5d | 2025-09-09 | 2025-09-15 | 36, 22 |  |  |  | 292d |  | Traffic Design Engineer | 37.5h |  |
| 132 | 1.23.7 | 7.0 Determine Work Zone Significance |  | 10d | 2025-07-31 | 2025-08-13 | 78, 90FS-20d |  |  |  | 314d |  | Roadway Design Lead | 75h |  |
| 133 | 1.24 | **1RR2 Begin Railroad Coordination** |  | 73d | 2025-07-31 | 2025-11-11 |  |  |  |  | 251d |  |  | 487.5h |  |
| 134 | 1.24.1 | 1.0 Initiate Railroad Coordination |  | 50d | 2025-07-31 | 2025-10-09 | 78 |  |  |  | 274d |  | Railroad Coordinator | 375h |  |
| 135 | 1.24.2 | 2.0 Prepare Railroad Cost Estimate |  | 15d | 2025-10-22 | 2025-11-11 | 97 |  |  |  | 251d |  | Railroad Coordinator | 112.5h |  |
| 136 | 1.25 | **1PM5 Hold Scoping Meeting and L&G Field Review** |  | 40d | 2025-10-22 | 2025-12-19 |  |  |  |  | 5d |  |  | 412.5h |  |
| 137 | 1.25.1 | 1.0 Review Period (Complete Comment Form) |  | 15d | 2025-10-22 | 2025-11-11 | 97 |  |  |  | 5d | 0d | TDOT Project Manager | 112.5h |  |
| 138 | 1.25.2 | 2.0 Quality Assurance Evaluation |  | 15d | 2025-10-22 | 2025-11-11 | 97 |  |  |  | 251d |  | Regional Quality Team Lead | 112.5h |  |
| 139 | 1.25.3 | 3.0 Compile Comments and Hold Meeting |  | 5d | 2025-11-12 | 2025-11-19 | 137 | 2022-07-07 | 2022-07-20 | 10.67d | 5d | 0d | TDOT Project Manager | 37.5h | Yes |
| 140 | 1.25.4 | 4.0 Estimate the Project Using the Line and Grade Package |  | 15d | 2025-11-20 | 2025-12-12 | 130, 139 |  |  |  | 176d | 0d | TDOT Project Manager | 112.5h |  |
| 141 | 1.25.5 | 5.0 Determine Need for Value Engineering |  | 5d | 2025-12-15 | 2025-12-19 | 137, 140 |  |  |  | 176d | 0d | TDOT Project Manager | 37.5h |  |
| 142 | 2 | Stage 1 Complete | milestone | 0d | 2025-11-19 | 2025-11-19 | 139 |  |  |  | 246d |  |  |  |  |
| 143 | 3 | **STAGE 2- FOOTPRINT ESTABLISHED** |  | 339.87d? | 2025-06-02 | 2026-10-12 |  |  |  |  | 23.87d |  |  | 12172.5h |  |
| 144 | 3.1 | **2PM1 Manage Project** |  | 339.87d? | 2025-06-02 | 2026-10-12 |  |  |  |  | 25d |  |  | 2107.5h |  |
| 145 | 3.1.1 | **1.0 Develop Project Management Plan** |  | 118d | 2025-07-31 | 2026-01-23 |  |  |  |  | 206d |  |  | 262.5h |  |
| 146 | 3.1.1.1 | - Develop PMP |  | 20d | 2025-07-31 | 2025-08-27 | 2, 18 |  |  |  | 304d |  | TDOT Project Manager | 150h |  |
| 147 | 3.1.1.2 | - PMP Update 1 |  | 10d | 2025-12-15 | 2025-12-30 | 140 |  |  |  | 221d |  | TDOT Project Manager | 75h |  |
| 148 | 3.1.1.3 | - PMP Update 2 |  | 5d | 2026-01-16 | 2026-01-23 | 169 |  |  |  | 206d |  | TDOT Project Manager | 37.5h |  |

Notes:
- 131: If needed
- 132: May delete, but coordinate with similar 1RD1 task
- 136: This could serve as the Line and Grade field review, but the scoping meeting can also be completed earlier in Stage 1 (as a separate meeting).
- 139: Confirm scope, schedule, budget
- 145: This activity also covers 3PM1 and 4PM1

| ID | WBS | Task | Duration | Start | Finish | Predecessors | Total slack | Free slack | Resources | Work |
| --- | --- | --- | --- | --- | --- | --- | --- | --- | --- | --- |
| 149 | 3.1.2 | **2.0 Report Project Status** | 5d | 2025-06-02 | 2025-06-09 |  | 359.87d |  |  | 75h |
| 150 | 3.1.2.1 | - Status Update 1 | 5d | 2025-06-02 | 2025-06-09 |  | 359.87d |  | TDOT Project Manager | 37.5h |
| 151 | 3.1.2.2 | - Status Update 2 | 5d | 2025-06-02 | 2025-06-09 |  | 359.87d |  | TDOT Project Manager | 37.5h |
| 152 | 3.1.3 | **3.0 Finalize Local Government Agreements** | 178.87d | 2025-06-02 | 2026-02-23 |  | 141d |  |  | 750h |
| 153 | 3.1.3.1 | - Enter Agreement 1 Name | 80d | 2025-10-22 | 2026-02-23 | 97 | 141d |  | TDOT Project Manager | 600h |
| 154 | 3.1.3.2 | - Enter Agreement 2 Name | 20d | 2025-06-02 | 2025-07-01 |  | 299.87d |  | TDOT Project Manager | 150h |
| 155 | 3.1.4 | **4.0 Perform Letting Readiness Assessment** | 111d | 2026-02-17 | 2026-07-24 |  | 80d |  |  | 187.5h |
| 156 | 3.1.4.1 | - Functional Design Plans | 10d | 2026-02-17 | 2026-03-02 | 186 | 181d |  | TDOT Project Manager | 75h |
| 157 | 3.1.4.2 | - Plan-in-Hand | 10d | 2026-04-30 | 2026-05-13 | 284 | 130d |  | TDOT Project Manager | 75h |
| 158 | 3.1.4.3 | - Construction Documents | 5d | 2026-07-20 | 2026-07-24 | 339 | 80d |  | TDOT Project Manager | 37.5h |
| 159 | 3.1.5 | 5.0 Support Value Engineering Efforts | 50d | 2025-12-22 | 2026-03-09 | 141, 139 | 176d |  | TDOT Project Manager | 375h |
| 160 | 3.1.6 | 6.0 Manage Consultant Contracts and Modifications | 1d? | 2025-07-31 | 2025-07-31 | 3, 22 | 323d |  | TDOT Project Manager | 7.5h |
| 161 | 3.1.7 | **7.0 Request and Obtain Authorization of Funds** | 141d | 2026-03-24 | 2026-10-12 |  | 25d |  |  | 450h |
| 162 | 3.1.7.1 | - PE-D | 15d | 2026-03-24 | 2026-04-14 | 251, 169 | 151d |  | TDOT Project Manager | 112.5h |
| 163 | 3.1.7.2 | - ROW Acquisition | 15d | 2026-03-24 | 2026-04-14 | 251, 169 | 151d |  | TDOT Project Manager | 112.5h |
| 164 | 3.1.7.3 | - Utility Relocation | 15d | 2026-03-24 | 2026-04-14 | 251, 169 | 151d |  | TDOT Project Manager | 112.5h |
| 165 | 3.1.7.4 | - Confirm Construction Authorization | 15d | 2026-09-22 | 2026-10-12 | 355, 339 | 25d |  | TDOT Project Manager | 112.5h |
| 166 | 3.2 | **2PM2 Complete Project Commitment Document (PCD)** | 35d | 2025-11-20 | 2026-01-15 |  | 196d |  |  | 225h |
| 167 | 3.2.1 | 1.0 Verify Schedule | 10d | 2025-11-20 | 2025-12-05 | 139, 9, 255, 197 | 211d | 15d | TDOT Project Manager | 75h |
| 168 | 3.2.2 | 2.0 Verify Estimates | 10d | 2025-12-15 | 2025-12-30 | 140, 104, 196 | 196d | 0d | TDOT Project Manager | 75h |
| 169 | 3.2.3 | 3.0 Finalize Project Commitment Document (PCD) | 10d | 2026-01-02 | 2026-01-15 | 168, 167 | 196d | 0d | TDOT Project Manager | 75h |
| 170 | 3.3 | **2SY1 Complete SUE and Requested Staking** | 65d | 2025-10-15 | 2026-01-23 |  | 25d |  |  | 375h |
| 171 | 3.3.1 | 1.0 Incorporate SUE Level A and B Request into Survey | 40d | 2025-11-20 | 2026-01-23 | 207, 175 | 25d | 0d | Survey Lead | 300h |
| 172 | 3.3.2 | 2.0 Stake Sounding Holes | 10d | 2025-10-15 | 2025-10-28 | 122 | 50d | 0d | Survey Lead | 75h |

Notes:
- 150: Tie up based on occurrence/need
- 151: Tie up based on occurrence/need
- 153: Check duration and logic for each project
- 154: Need to tie up if additional agreements are needed
- 160: Runs the length of the project; could be inactivated for each project
- 161: These authorizations can also be split up, but regardless need to be confirmed prior to request.
- 165: Need updated design estimate to request authorization, but at the end of the process

| ID | WBS | Task | Duration | Start | Finish | Predecessors | Total slack | Free slack | Resources | Work |
| --- | --- | --- | --- | --- | --- | --- | --- | --- | --- | --- |
| 173 | 3.4 | **2RD1 Develop Functional Design Plans** | 130d? | 2025-09-24 | 2026-04-07 |  | 35d |  |  | 1177.5h |
| 174 | 3.4.1 | 1.0 Develop a Utility Impact/Conflict Matrix | 15d | 2025-10-22 | 2025-11-11 | 103, 97 | 25d | 0d | Roadway Design Lead | 112.5h |
| 175 | 3.4.2 | 2.0 Identify Initial Subsurface Utility Engineering (SUE) Needs | 15d | 2025-10-22 | 2025-11-11 | 97 | 30d | 5d | Roadway Design Lead | 112.5h |
| 176 | 3.4.3 | **3.0 Request Pavement Design** | 30d | 2025-10-16 | 2025-12-01 |  | 89d |  |  | 82.5h |
| 177 | 3.4.3.1 | - Request pavement design | 1d | 2025-10-16 | 2025-10-16 | 214FS-10d | 269d |  | Roadway Design Lead | 7.5h |
| 178 | 3.4.3.2 | - Receive and incorporate pavement design | 10d | 2025-11-13 | 2025-12-01 | 193 | 69d | 44d | Roadway Design Lead | 75h |
| 179 | 3.4.4 | 4.0 Document Design Exceptions and Waivers | 20d | 2025-10-22 | 2025-11-19 | 97 | 75d | 50d | Roadway Design Lead | 150h |
| 180 | 3.4.5 | 5.0 Incorporate SUE Data and Lead Internal Design Deconfliction Meeting | 10d | 2026-01-26 | 2026-02-06 | 171 | 25d | 0d | Roadway Design Lead | 75h |
| 181 | 3.4.6 | 6.0 Develop Utility Coordination Plans | 5d | 2026-01-16 | 2026-01-23 | 186FS-20d | 45d | 40d | Roadway Design Lead | 37.5h |
| 182 | 3.4.7 | 7.0 Develop Design and Sketches for Permit Applications | 30d | 2025-11-12 | 2025-12-30 | 97, 255 | 0d |  | Roadway Design Lead | 225h |
| 183 | 3.4.8 | 8.0 Develop Conceptual Traffic Control Strategies | 20d | 2025-10-22 | 2025-11-19 | 97 | 75d | 0d | Roadway Design Lead | 150h |
| 184 | 3.4.9 | 9.0 Develop the Functional Design Plans | 1d? | 2025-10-22 | 2025-10-22 | 97 | 94d | 69d | Roadway Design Lead | 7.5h |
| 185 | 3.4.10 | 10.0 Coordinate Geotechnical Analysis for Noise and Retaining Walls | 10d | 2025-09-24 | 2025-10-07 | 97FS-20d | 50d | 0d | Roadway Design Lead | 75h |
| 186 | 3.4.11 | 11.0 Compile the Functional Design Plans and Participate in the Field Review | 5d | 2026-02-09 | 2026-02-13 | 272, 215, 247, 268, 270, 271, 183, 184, 191, 228, 227, 231, 178, 179, 180 | 25d | 0d | Roadway Design Lead | 37.5h |
| 187 | 3.4.12 | 12.0 Revise and Submit Updated Functional Design Plans | 15d | 2026-03-17 | 2026-04-07 | 277 | 25d | 0d | Roadway Design Lead | 112.5h |
| 188 | 3.5 | **2RD2 Conduct Design Public Meeting** | 66d | 2025-10-22 | 2026-02-02 |  | 29d |  |  | 495h |
| 189 | 3.5.1 | 1.0 Prepare for the Design Public Meeting | 55d | 2025-10-22 | 2026-01-15 | 97 | 29d | 0d | Roadway Design Lead | 412.5h |
| 190 | 3.5.2 | 2.0 Hold Design Public Meeting | 1d | 2026-01-16 | 2026-01-16 | 189 | 29d | 0d | Roadway Design Lead | 7.5h |
| 191 | 3.5.3 | 3.0 Process Design Public Meeting Transcript | 10d | 2026-01-20 | 2026-02-02 | 190 | 29d | 4d | Roadway Design Lead | 75h |
| 192 | 3.6 | **2PV1 Provide Pavement Design** | 10d | 2025-10-30 | 2025-11-12 |  | 69d |  |  | 75h |
| 193 | 3.6.1 | 1.0 Provide Pavement Design | 10d | 2025-10-30 | 2025-11-12 | 214 | 69d | 0d | Pavement Team Lead | 75h |
| 194 | 3.7 | **2RW1 Initiate Pre-Acquisition Activities** | 40d | 2025-10-22 | 2025-12-19 |  | 80d |  |  | 675h |
| 195 | 3.7.1 | 1.0 Prepare CSRP | 15d | 2025-10-22 | 2025-11-11 | 97 | 245d | 0d | ROW Acquisition/Relocation Team Lead | 112.5h |
| 196 | 3.7.2 | 2.0 Prepare Right-of-Way Estimate (L&G) | 15d | 2025-10-22 | 2025-11-11 | 97 | 216d | 20d | Regional ROW Appraisal Team Lead | 112.5h |
| 197 | 3.7.3 | 3.0 Perform Title Searches | 20d | 2025-10-22 | 2025-11-19 | 97 | 80d | 0d | ROW Acquisition/Relocation Team Lead | 150h |
| 198 | 3.7.4 | 4.0 Initiate Private Property Owner Utility Adjustment | 20d | 2025-11-20 | 2025-12-19 | 97, 197 | 80d | 35d | ROW Acquisition/Relocation Team Lead | 150h |
| 199 | 3.7.5 | 5.0 Initiate PGI Field Work | 20d | 2025-11-20 | 2025-12-19 | 197, 97 | 80d | 35d | ROW Acquisition/Relocation Team Lead | 150h |

Notes:
- 174: Or use related line under 2UT1
- 180: See related line under 2UT1 for both the Utility Coordinator and Roadway Lead to coordinate this step
- 181: This could begin in Stage 2 or early Stage 3. Consider advancing at risk if the project is under an accelerated schedule.
- 184: Duration depends on size of the project/complexity of design.
- 189: Public meeting requests need to be submitted 8 weeks before the public meeting to CRD. Public Hearing requests must be submitted to CRD with this checklist ten (10) weeks in advance of hearing date.
- 197: Duration will depend on number of acquisitions/relocations
- 199: Duration will depend on number of acquisitions/relocations

| ID | WBS | Task | Duration | Start | Finish | Predecessors | Total slack | Free slack | Resources | Work |
| --- | --- | --- | --- | --- | --- | --- | --- | --- | --- | --- |
| 200 | 3.8 | **2PM3 Conduct ROW Strategy Meeting(s)** | 158.87d | 2025-06-02 | 2026-01-23 |  | 206d |  |  | 307.5h |
| 201 | 3.8.1 | 2.0 Hold Meeting and Document/Distribute Minutes | 40d | 2025-11-20 | 2026-01-23 | 97, 197 | 206d |  | TDOT Project Manager | 300h |
| 202 | 3.8.2 | 3.0 Attend ROW Site Visit and Collect Feedback | 1d | 2025-06-02 | 2025-06-03 |  | 363.87d |  | TDOT Project Manager | 7.5h |
| 203 | 3.9 | **2RW2 Execute ROW Proposal** | 2d? | 2025-10-22 | 2025-10-23 |  | 219d |  |  | 15h |
| 204 | 3.9.1 | 1.0 Prepare/Submit ROW Proposal | 1d? | 2025-10-22 | 2025-10-22 | 97 | 219d | 0d | ROW Acquisition/Relocation Team Lead | 7.5h |
| 205 | 3.9.2 | 2.0 Receive ROW Proposal and Distribute for Execution | 1d? | 2025-10-23 | 2025-10-23 | 204 | 219d |  | ROW Acquisition/Relocation Team Lead | 7.5h |
| 206 | 3.10 | **2UT1 Initiate Utility Pre-Acquisition Activities** | 90d | 2025-10-22 | 2026-03-09 |  | 40d |  |  | 337.5h |
| 207 | 3.10.1 | 1.0 Coordinate/Request Needed SUE | 5d | 2025-11-12 | 2025-11-19 | 174 | 25d | 0d | Utility Coordinator | 37.5h |
| 208 | 3.10.2 | 2.0 Confirm Utility Estimate | 15d | 2026-02-17 | 2026-03-09 | 186 | 176d |  | Utility Coordinator | 112.5h |
| 209 | 3.10.3 | 3.0 Develop a Utility Impact/Conflict Matrix | 15d | 2025-10-22 | 2025-11-11 | 103, 97 | 251d |  | Utility Coordinator | 112.5h |
| 210 | 3.10.4 | 4.0 Review SUE Data and Attend Internal Design Deconfliction Meeting | 10d | 2026-01-26 | 2026-02-06 | 171 | 196d |  | Utility Coordinator | 75h |
| 211 | 3.11 | **2GT1 Complete the Soils and Geology Report** | 105.87d? | 2025-06-02 | 2025-10-30 |  | 162.87d |  |  | 105h |
| 212 | 3.11.1 | 1.0 Conduct Site Exploration for Soils and Geology Report | 1d? | 2025-10-15 | 2025-10-15 | 122 | 78d | 9d | Lead Geotechnical Engineer/Geologist | 7.5h |
| 213 | 3.11.2 | 2.0 Select the Appropriate Laboratory Testing Program | 10d | 2025-10-15 | 2025-10-28 | 122 | 69d | 0d | Lead Geotechnical Engineer/Geologist | 75h |
| 214 | 3.11.3 | 3.0 Develop the Soils and Geology Report | 1d? | 2025-10-29 | 2025-10-29 | 212, 213 | 69d | 0d | Lead Geotechnical Engineer/Geologist | 7.5h |
| 215 | 3.11.4 | 4.0 Develop Associated Geotechnical Sheet (G-Sheets) | 1d? | 2025-10-30 | 2025-10-30 | 214 | 88d | 63d | Lead Geotechnical Engineer/Geologist | 7.5h |
| 216 | 3.11.5 | 5.0 Develop Supporting Project Addenda | 1d? | 2025-06-02 | 2025-06-03 |  | 363.87d |  | Lead Geotechnical Engineer/Geologist | 7.5h |
| 217 | 3.12 | **2GT2 Complete Foundation Reports** | 90d? | 2025-10-29 | 2026-03-16 |  | 50d |  |  | 840h |
| 218 | 3.12.1 | 1.0 Conduct Site Exploration for Structures | 60d | 2025-10-29 | 2026-01-30 | 122, 172 | 50d | 0d | Lead Geotechnical Engineer/Geologist | 450h |
| 219 | 3.12.2 | 2.0 Complete and Submit Foundation Report for Retaining Wall(s) | 30d | 2026-02-02 | 2026-03-16 | 218 | 50d | 15d | Lead Geotechnical Engineer/Geologist | 225h |
| 220 | 3.12.3 | 3.0 Complete and Submit Foundation Report for Noise Wall(s) | 1d? | 2026-02-02 | 2026-02-02 | 218 | 79d | 44d | Lead Geotechnical Engineer/Geologist | 7.5h |
| 221 | 3.12.4 | 4.0 Complete and Submit Standard Report for Signs, Lighting, Signals, ITS, and High-Mast Lighting | 20d | 2026-02-02 | 2026-03-02 | 218 | 60d | 25d | Lead Geotechnical Engineer/Geologist | 150h |
| 222 | 3.12.5 | 5.0 Complete and Submit Foundation Report for Bridges | 1d? | 2026-02-02 | 2026-02-02 | 218 | 79d | 44d | Lead Geotechnical Engineer/Geologist | 7.5h |
| 223 | 3.13 | **2ST1 Complete Hydraulic Design** | 60d | 2025-10-22 | 2026-01-23 |  | 35d |  |  | 787.5h |
| 224 | 3.13.1 | 1.0 Verify Proposed Grade and Estimate Hydraulic Structure Sizes | 15d | 2025-10-22 | 2025-11-11 | 97 | 35d | 0d | Hydraulic Lead | 112.5h |
| 225 | 3.13.2 | 2.0 Develop Draft Hydraulic Layout | 25d | 2025-11-12 | 2025-12-19 | 224 | 35d | 0d | Hydraulic Lead | 187.5h |
| 226 | 3.13.3 | 3.0 Hydraulically Model Proposed Conditions, Evaluate Proposals, and Select Appropriate Structure | 25d | 2025-11-12 | 2025-12-19 | 224 | 35d | 0d | Hydraulic Lead | 187.5h |
| 227 | 3.13.4 | 4.0 Finalize Hydraulic Layout | 20d | 2025-12-22 | 2026-01-23 | 225, 226 | 35d | 10d | Hydraulic Lead | 150h |
| 228 | 3.13.5 | 5.0 Finalize Hydraulic Design Information | 20d | 2025-12-22 | 2026-01-23 | 225, 226 | 35d | 10d | Hydraulic Lead | 150h |

Notes:
- 201: Meant to either manage meeting-by-meeting or over the course of the meetings
- 202: Various (as many as needed); tie up logic accordingly
- 204: Another name for 2PM1's Local Agency agreements
- 205: Another name for 2PM1's Local Agency agreements
- 207: Coordinate with 2RD1 Task 2.0
- 209: Or use related line under 2RD1
- 210: See related line under 2RD1 for both the Utility Coordinator and Roadway Lead to coordinate this step
- 216: Tie up logic if needed
- 221: See PDN; this is likely going to just entail getting the borings and holding them for contractor reference; typically no formal report is needed for signal, signs, and lighting (with the exception of high-mast).

| ID | WBS | Task | Duration | Start | Finish | Predecessors | Total slack | Free slack | Resources | Work | Text1 |
| --- | --- | --- | --- | --- | --- | --- | --- | --- | --- | --- | --- |
| 229 | 3.14 | **2ST2 Develop Preliminary Bridge Plans** | 75d | 2025-09-24 | 2026-01-15 |  | 40d |  |  | 450h |  |
| 230 | 3.14.1 | 1.0 Review Proposed Grade and Alignment for Non-Hydraulic Crossings | 15d | 2025-10-22 | 2025-11-11 | 97 | 40d | 0d | Structural Design Lead | 112.5h |  |
| 231 | 3.14.2 | 2.0 Develop Preliminary Bridge Layouts | 40d | 2025-11-12 | 2026-01-15 | 230 | 40d | 15d | Structural Design Lead | 300h |  |
| 232 | 3.14.3 | 3.0 Coordinate Geotechnical Analysis for Bridges | 5d | 2025-09-24 | 2025-09-30 | 97FS-20d | 55d | 5d | Structural Design Lead | 37.5h |  |
| 233 | 3.15 | **2EN1 Complete Environmental Resource Effects/Impacts** | 138.87d? | 2025-06-02 | 2025-12-19 |  | 5d | 0d |  | 2152.5h |  |
| 234 | 3.15.1 | 1.0 Complete Necessary Resource Effect/Impact Evaluations (all other resources) | 1d? | 2025-11-20 | 2025-11-20 | 139 | 24d |  | Environmental Technical Lead | 7.5h |  |
| 235 | 3.15.2 | 2.0 Complete Historic Preservation Effects Study | 1d? | 2025-11-20 | 2025-11-20 | 106, 139 | 24d |  | Environmental Technical Lead | 7.5h |  |
| 236 | 3.15.3 | **3.0 Archeological** | 138.87d | 2025-06-02 | 2025-12-19 |  | 5d |  |  | 1050h |  |
| 237 | 3.15.3.1 | - No Effects Determination | 20d | 2025-11-20 | 2025-12-19 | 107, 139 | 5d |  | Environmental Technical Lead | 150h |  |
| 238 | 3.15.3.2 | - Complete Phase Two Archaeological Eligibility Study | 120d | 2025-06-02 | 2025-11-21 |  | 23.87d |  | Environmental Technical Lead | 900h |  |
| 239 | 3.15.4 | **4.0 Complete Air Quality Impact Study** | 20d? | 2025-11-20 | 2025-12-19 | 112, 139 | 5d |  |  | 157.5h |  |
| 240 | 3.15.4.1 | - Complete Technical Report (No Effects) | 20d | 2025-11-20 | 2025-12-19 |  | 5d |  | Environmental Technical Lead | 150h |  |
| 241 | 3.15.4.2 | - Complete Air Quality Impact Study | 1d? | 2025-11-20 | 2025-11-20 |  | 24d |  | Environmental Technical Lead | 7.5h |  |
| 242 | 3.15.5 | **5.0 Noise** | 120d? | 2025-06-02 | 2025-11-21 |  | 23.87d |  |  | 907.5h |  |
| 243 | 3.15.5.1 | - Complete Technical Report (No Effects) | 1d? | 2025-11-20 | 2025-11-20 | 113, 139 | 24d |  | Environmental Technical Lead | 7.5h |  |
| 244 | 3.15.5.2 | - Complete Noise Abatement Study | 120d | 2025-06-02 | 2025-11-21 |  | 23.87d |  | Environmental Technical Lead | 900h |  |
| 245 | 3.15.6 | 6.0 Complete Ecology Environmental Boundaries Report | 1d? | 2025-11-20 | 2025-11-20 | 109, 139 | 24d |  | Environmental Technical Lead | 7.5h |  |
| 246 | 3.15.7 | 7.0 Complete Hazardous Materials Study | 1d? | 2025-11-20 | 2025-11-20 | 114, 139 | 24d |  | Environmental Technical Lead | 7.5h |  |
| 247 | 3.15.8 | 8.0 Confirm Multimodal Compliance Determination | 1d? | 2025-08-26 | 2025-08-26 | 43 | 84d |  | Environmental Technical Lead | 7.5h |  |
| 248 | 3.16 | **2EN2 Complete Environmental Document** | 135d | 2025-10-30 | 2026-05-20 |  | 29d |  |  | 750h |  |
| 249 | 3.16.1 | 1.0 Review/Finalize Purpose and Need Statement | 10d | 2025-10-30 | 2025-11-12 | 96SS+10d | 29d | 24d | NEPA Lead | 75h |  |
| 250 | 3.16.2 | 2.0 Complete Environmental Document | 20d | 2025-12-22 | 2026-01-23 | 233, 249 | 5d | 0d | NEPA Lead | 150h |  |
| 251 | 3.16.3 | 3.0 Receive Approval (as applicable) | 40d | 2026-01-26 | 2026-03-23 | 250 | 5d | 0d | NEPA Lead | 300h |  |
| 252 | 3.16.4 | 4.0 Functional Design Plans Review (if needed): Complete Environmental Document Re-Evaluation | 15d | 2026-02-17 | 2026-03-09 | 186 | 131d |  | NEPA Lead | 112.5h | Yes |
| 253 | 3.16.5 | 5.0 Plan-in-Hand Review: Complete Environmental Document Re-Evaluation | 15d | 2026-04-30 | 2026-05-20 | 284 | 80d |  | NEPA Lead | 112.5h | Yes |

Notes:
- 233: Depending on the resources in the ETSA, the use or duration for a # of these studies could add considerable schedule time. The studies are required will not be known until the end of Stage 1/start of Stage 2. Adjust durations ASAP.
- 235: Section 106 Effects Assessment and Concurrence
- 238: Tie up logic with related 1EN1 task if a Phase 2 is needed. This will become a driver for Env.
- 241: Tie up logic with related 1EN1 task if an air quality study is needed.
- 244: Tie up logic with related 1EN1 task if a noise abatement study is needed.
- 251: Duration assumes FHWA approval of NEPA document; if TEER this can be shorter (~15 days)
- 252: This could be 3 weeks to 6 months depending on impacts/changes in design. This activity is optional depending on if the environmental document is complete at the time the plans are submitted for review.
- 253: This could be 3 weeks to 6 months depending on impacts/changes in design.

| ID | WBS | Task | Type | Duration | Start | Finish | Predecessors | Total slack | Free slack | Resources | Work |
| --- | --- | --- | --- | --- | --- | --- | --- | --- | --- | --- | --- |
| 254 | 3.17 | **2EN3 Conduct Permit Assessment** |  | 188.87d? | 2025-06-02 | 2026-03-09 |  | 98.87d |  |  | 352.5h |
| 255 | 3.17.1 | 1.0 Complete Permit Assessment |  | 15d | 2025-10-22 | 2025-11-11 | 97, 110 | 0d |  | Environmental Permit Lead | 112.5h |
| 256 | 3.17.2 | 2.0 Finalize Plans and Sketch Review and Prepare Permittable Plans Package |  | 1d? | 2026-01-02 | 2026-01-02 | 255, 182 | 0d |  | Environmental Permit Lead | 7.5h |
| 257 | 3.17.3 | 3.0 Evaluate Permittable Plans Package |  | 15d | 2026-01-05 | 2026-01-26 | 256 | 0d |  | Environmental Permit Lead | 112.5h |
| 258 | 3.17.4 | 4.0 Review EPSC Plans in the Functional Design Plans |  | 15d | 2026-02-17 | 2026-03-09 | 186 | 176d |  | Environmental Permit Lead | 112.5h |
| 259 | 3.17.5 | 5.0 Lead Pre-application meeting with USACE and TDEC |  | 1d? | 2025-06-02 | 2025-06-03 |  | 363.87d |  | Environmental Permit Lead | 7.5h |
| 260 | 3.18 | **2PM4 Conduct Permit Strategy Meeting(s)** |  | 138.87d? | 2025-06-02 | 2025-12-19 |  | 226d |  |  | 307.5h |
| 261 | 3.18.1 | 1.0 Hold Meeting |  | 40d | 2025-10-22 | 2025-12-19 | 109, 97 | 226d |  | TDOT Project Manager | 300h |
| 262 | 3.18.2 | 2.0 Verify Permit(s) Are Complete and Submitted |  | 1d? | 2025-06-02 | 2025-06-03 |  | 363.87d |  | TDOT Project Manager | 7.5h |
| 263 | 3.19 | **2EN4 Complete Mitigation Assessment and Initiate Mitigation Design** |  | 31d? | 2025-10-22 | 2025-12-08 |  | 30d |  |  | 345h |
| 264 | 3.19.1 | **1.0 Complete Mitigation Assessment** |  | 30d | 2025-10-22 | 2025-12-05 |  | 30d |  |  | 337.5h |
| 265 | 3.19.1.1 | - Complete Mitigation Assessment |  | 15d | 2025-10-22 | 2025-11-11 | 109, 97 | 251d |  | Engineering Mitigation Lead | 112.5h |
| 266 | 3.19.1.2 | - Evaluate mitigation (Bank or In-Lieu fee) availability and permittee responsibilities |  | 15d | 2025-10-22 | 2025-11-11 | 109, 97 | 30d | 0d | Engineering Mitigation Lead | 112.5h |
| 267 | 3.19.1.3 | - Identify Need for Concurrent Project |  | 15d | 2025-11-12 | 2025-12-05 | 266 | 30d | 0d | Engineering Mitigation Lead | 112.5h |
| 268 | 3.19.2 | 2.0 Develop Preliminary Mitigation Plan (30% designed) |  | 1d? | 2025-12-08 | 2025-12-08 | 267 | 30d |  | Mitigation Designer | 7.5h |
| 269 | 3.20 | **2TD1 Prepare ITS, Signals, and Lighting Sheets** |  | 1d? | 2025-10-22 | 2025-10-22 |  | 94d |  |  | 30h |
| 270 | 3.20.1 | 1.0 Prepare ITS Sheets |  | 1d? | 2025-10-22 | 2025-10-22 | 97 | 94d | 69d | Traffic Design Engineer | 7.5h |
| 271 | 3.20.2 | 2.0 Prepare Signal Sheets |  | 1d? | 2025-10-22 | 2025-10-22 | 97 | 94d | 69d | Traffic Design Engineer | 7.5h |
| 272 | 3.20.3 | 3.0 Prepare Lighting Sheets |  | 1d? | 2025-10-22 | 2025-10-22 | 97 | 94d | 69d | Traffic Design Engineer | 7.5h |
| 273 | 3.20.4 | 4.0 Oversee Development of the Conceptual Traffic Control Strategies |  | 1d? | 2025-10-22 | 2025-10-22 | 183SS | 265d |  | Traffic Design Engineer | 7.5h |
| 274 | 3.21 | **2PM5 Hold Functional Design Plans Field Review Meeting** |  | 20d | 2026-02-17 | 2026-03-16 |  | 25d |  |  | 262.5h |
| 275 | 3.21.1 | 1.0 Review Period (Complete Comment Form) |  | 15d | 2026-02-17 | 2026-03-09 | 186 | 25d | 0d | TDOT Project Manager | 112.5h |
| 276 | 3.21.2 | 2.0 Quality Assurance Evaluation |  | 15d | 2026-02-17 | 2026-03-09 | 186 | 176d |  | Regional Quality Team Lead | 112.5h |
| 277 | 3.21.3 | 3.0 Compile Comments, Hold Meeting, and Document/Distribute Minutes |  | 5d | 2026-03-10 | 2026-03-16 | 275 | 25d | 0d | TDOT Project Manager | 37.5h |
| 278 | 4 | Stage 2 Complete | milestone | 0d | 2026-04-07 | 2026-04-07 | 187 | 156d |  |  |  |

Notes:
- 256: Adjust duration based on complexity of permit impacts.
- 258: Procure six weeks prior to Functional Plan turn-in
- 259: Optional task that will help in coordinating with USACE and TDEC on the project details and upcoming permit application and content.
- 261: Meant to either manage meeting-by-meeting or over the course of the meetings
- 262: Various (as many as needed)
- 266: If needed based on impacts determined from the assessment
- 267: If needed (meaning TDOT is not using credits/bank)
- 268: If needed (meaning TDOT is not using credits/bank)
- 274: 4 weeks (20 working days) is default timing broken down as follows: ...

| ID | WBS | Task | Duration | Start | Finish | Predecessors | Total slack | Free slack | Resources | Work |
| --- | --- | --- | --- | --- | --- | --- | --- | --- | --- | --- |
| 279 | 5 | **STAGE 3- PLAN-IN-HAND** | 320.87d? | 2025-06-02 | 2026-09-15 |  | 44d |  |  | 6450h |
| 280 | 5.1 | **3RD1 Complete Plan-in-Hand Design** | 51d? | 2026-02-17 | 2026-04-29 |  | 34d |  |  | 202.5h |
| 281 | 5.1.1 | 1.0 Develop ROW Acquisition Exhibits | 20d | 2026-02-17 | 2026-03-16 | 186 | 65d | 25d | Roadway Design Lead | 150h |
| 282 | 5.1.2 | 2.0 Finalize the TMP & Complete the Temporary Traffic Control Plans | 1d? | 2026-04-08 | 2026-04-08 | 187 | 25d | 0d | Roadway Design Lead | 7.5h |
| 283 | 5.1.3 | 3.0 Complete Plan-in-Hand Plans | 1d? | 2026-04-08 | 2026-04-08 | 187 | 34d | 0d | Roadway Design Lead | 7.5h |
| 284 | 5.1.4 | 4.0 Compile the Plan-in-Hand Plans and Participate in the Field Review | 5d | 2026-04-23 | 2026-04-29 | 283, 282, 295, 300, 310, 311, 323, 324, 325, 326, 328 | 25d | 0d | Roadway Design Lead | 37.5h |
| 285 | 5.2 | **3UT1 Perform Utility Coordination** | 320.87d? | 2025-06-02 | 2026-09-15 |  | 44d |  |  | 1140h |
| 286 | 5.2.1 | 1.0 Distribute Utility Coordination Plans | 2d | 2026-03-24 | 2026-03-25 | 181, 251 | 5d | 0d | Utility Coordinator | 15h |
| 287 | 5.2.2 | 2.0 Conduct Utility Plan Review Kickoff Meeting | 2d | 2026-04-24 | 2026-04-27 | 288 | 142d |  | Utility Coordinator | 15h |
| 288 | 5.2.3 | 3.0 Approve Engineering Packages | 20d | 2026-03-26 | 2026-04-23 | 286 | 142d | 0d | Utility Coordinator | 150h |
| 289 | 5.2.4 | 4.0 Complete 120-day Utility Review and Process Relocation Contract Requests | 84d | 2026-03-26 | 2026-07-24 | 286 | 5d | 0d | Utility Coordinator | 630h |
| 290 | 5.2.5 | 5.0 Submit Rainbows to Environmental | 5d | 2026-07-27 | 2026-07-31 | 289 | 9d | 0d | Utility Coordinator | 37.5h |
| 291 | 5.2.6 | **6.0 Put Utilities to Work** | 36d? | 2026-07-27 | 2026-09-15 |  | 44d |  |  | 270h |
| 292 | 5.2.6.1 | - Generate and Execute Relocation Contract | 25d | 2026-07-27 | 2026-08-28 | 289 | 44d | 0d | Utility Coordinator | 187.5h |
| 293 | 5.2.6.2 | - Send PTW Letter | 10d | 2026-08-31 | 2026-09-14 | 292 | 44d | 0d | Utility Coordinator | 75h |
| 294 | 5.2.6.3 | - Utility Advances Its Work | 1d? | 2026-09-15 | 2026-09-15 | 293 | 44d |  | Utility Coordinator | 7.5h |
| 295 | 5.2.7 | 7.0 Submit Construction Drawings to Design | 3d | 2025-06-02 | 2025-06-05 |  | 241.87d | 216.87d | Utility Coordinator | 22.5h |
| 296 | 5.3 | **3UT2 Prepare and Submit Utility Certification** | 30d | 2026-07-27 | 2026-09-04 |  | 5d |  |  | 225h |
| 297 | 5.3.1 | 1.0 Receive and Process Utility Deposits | 20d | 2026-07-27 | 2026-08-21 | 289 | 5d | 0d | Utility Coordinator | 150h |
| 298 | 5.3.2 | 2.0 Verify Utility Coordination is Complete | 10d | 2026-08-24 | 2026-09-04 | 297, 295 | 5d |  | Utility Coordinator | 75h |
| 299 | 5.4 | **3EN1 Finalize Stream & Wetland Mitigation Design** | 30d | 2026-02-17 | 2026-03-30 |  | 41d |  |  | 225h |
| 300 | 5.4.1 | 1.0 Finalize Mitigation Plans | 30d | 2026-02-17 | 2026-03-30 | 186, 268 | 41d | 16d | Mitigation Designer | 225h |
| 301 | 5.5 | **3EN2 Complete and Obtain Aquatic Permit** | 160d? | 2026-01-27 | 2026-09-14 |  | 0d |  |  | 1357.5h |
| 302 | 5.5.1 | 1.0 Complete Aquatic Permit Application (for the roadway project) | 40d | 2026-01-27 | 2026-03-24 | 268, 233FF, 257 | 0d |  | Environmental Permit Lead | 300h |
| 303 | 5.5.2 | 2.0 Obtain Aquatic Resource Permits | 120d | 2026-03-25 | 2026-09-14 | 302 | 0d |  | Environmental Permit Lead | 900h |
| 304 | 5.5.3 | 3.0 Modify or Complete Aquatic Permit Application (for Utility Relocation Impacts) | 20d | 2026-08-03 | 2026-08-28 | 290 | 9d | 0d | Environmental Permit Lead | 150h |
| 305 | 5.5.4 | 4.0 Obtain Aquatic Resource Permits (for utilities) | 1d? | 2026-08-31 | 2026-08-31 | 304 | 9d |  | Environmental Permit Lead | 7.5h |

Notes:
- 281: This could begin in Stage 2 or early Stage 3. Consider advancing at risk if the project is under an accelerated schedule.
- 283: Duration depends on size of the project/complexity of design, and can be run parallel with survey at risk.
- 286: This could also tie to Compile Functional Design Plans at the latest (see 2RD1, task 11.0); see PDN for what to show on the plans (namely permittable features as no relocation areas)
- 290: Note that this could be the plans for PIH submittal if the u-sheet (task 8.0) are not available yet
- 294: Length dependent on in-state contract vs. utility self-performed work
- 295: Typically tied to the utilities b-date package and can either be 26 weeks prior to letting or 60 days after receiving the a-date package (at then end of task 4.0 above).
- 302: Confirm tie to certain env. tech studies or the environmental document
- 303: Duration based on permit type determined under 2EN2. This duration could be 120 days to 18 months depending on what permit is needed and if a off-site mitigation site is needed....
- 304: Note the tie to receiving response from utility owners regarding relocation of their facilities. This is a late tie, notably if the relocation is going to impact a feature. This tie may drive a lag in the schedule that can be mitigated with early utility coordination and a clear depiction of where the utility cannot go on the Utility Coordination Plans (or Functional Design Plans).
- 305: Work with Permitting on mitigating this risk, which could considerably extend the schedule depending on utility impacts to features. This risk can be mitigated with early coordination and working with utilities to understand where they can and cannot move.

| ID | WBS | Task | Duration | Start | Finish | Predecessors | Total slack | Free slack | Resources | Work |
| --- | --- | --- | --- | --- | --- | --- | --- | --- | --- | --- |
| 306 | 5.6 | **4EN1 Complete and Obtain Stormwater Permit** | 60d | 2026-05-07 | 2026-07-31 |  | 30d |  |  | 450h |
| 307 | 5.6.1 | 1.0 Complete Stormwater Permit Application | 30d | 2026-05-07 | 2026-06-18 | 334FS-15d | 30d | 0d | Environmental Permit Lead | 225h |
| 308 | 5.6.2 | 2.0 Obtain NPDES Coverage | 30d | 2026-06-22 | 2026-07-31 | 307 | 30d |  | Environmental Permit Lead | 225h |
| 309 | 5.7 | **3ST1 Complete Structural Design** | 1d? | 2026-04-08 | 2026-04-08 |  | 35d |  |  | 15h |
| 310 | 5.7.1 | 1.0 Complete Retaining/Noise Wall Sheets | 1d? | 2026-04-08 | 2026-04-08 | 220, 219, 187, 244 | 35d | 10d | Structural Design Lead | 7.5h |
| 311 | 5.7.2 | 2.0 Complete Design and Detail Bridge Plans and Estimate | 1d? | 2026-04-08 | 2026-04-08 | 222, 187 | 35d | 10d | Structural Design Lead | 7.5h |
| 312 | 5.8 | **3RW1 Complete Appraisal and Initiate Acquisition** | 71d? | 2026-02-17 | 2026-05-28 |  | 40d |  |  | 390h |
| 313 | 5.8.1 | 1.0 Produce Preliminary Group Inspection (PGI) Report | 20d | 2026-02-17 | 2026-03-16 | 198, 199, 186 | 45d | 0d | Regional ROW Appraisal Team Lead | 150h |
| 314 | 5.8.2 | 2.0 Employ Fee Appraiser | 20d | 2026-03-17 | 2026-04-14 | 313 | 45d | 5d | TDOT HQ ROW Appraisal Manager | 150h |
| 315 | 5.8.3 | 3.0 Stake ROW | 10d | 2026-04-08 | 2026-04-21 | 313, 187 | 40d | 0d | ROW Acquisition/Relocation Team Lead | 75h |
| 316 | 5.8.4 | 4.0 Appraise Property | 1d? | 2026-04-22 | 2026-04-22 | 314, 281, 315 | 40d | 0d | ROW Acquisition/Relocation Team Lead | 7.5h |
| 317 | 5.8.5 | 5.0 Review Appraisals | 1d? | 2026-05-28 | 2026-05-28 | 316SS+25d | 40d | 0d | ROW Acquisition/Relocation Team Lead | 7.5h |
| 318 | 5.9 | **3RW2 Prepare and Submit ROW Certification** | 6d? | 2026-07-10 | 2026-07-17 |  | 40d |  |  | 52.5h |
| 319 | 5.9.1 | 1.0 Perform/Finish Acquiring Property | 1d? | 2026-07-10 | 2026-07-10 | 317SS+30d, 251 | 40d | 0d | ROW Acquisition/Relocation Team Lead | 7.5h |
| 320 | 5.9.2 | 2.0 Perform/Finish ROW Relocation | 1d? | 2026-07-10 | 2026-07-10 | 317SS+30d, 251 | 40d | 0d | ROW Acquisition/Relocation Team Lead | 7.5h |
| 321 | 5.9.3 | 3.0 Review ROW Acquisition Process, Verify/Update Schedule, and Issue ROW Certification | 5d | 2026-07-13 | 2026-07-17 | 319, 320 | 40d |  | ROW Acquisition/Relocation Team Lead | 37.5h |
| 322 | 5.10 | **3TD1 Complete Signal, Lighting, and ITS Device Design** | 11d? | 2026-04-08 | 2026-04-22 |  | 25d |  |  | 97.5h |
| 323 | 5.10.1 | 1.0 Complete Signal Design | 1d? | 2026-04-08 | 2026-04-08 | 221, 187 | 35d | 10d | Traffic Design Engineer | 7.5h |
| 324 | 5.10.2 | 2.0 Complete Lighting Design | 1d? | 2026-04-08 | 2026-04-08 | 221, 187 | 35d | 10d | Traffic Design Engineer | 7.5h |
| 325 | 5.10.3 | 3.0 Complete ITS Device Design | 1d? | 2026-04-08 | 2026-04-08 | 221, 187 | 35d | 10d | Traffic Design Engineer | 7.5h |
| 326 | 5.10.4 | 4.0 Review the TMP for Compliance | 10d | 2026-04-09 | 2026-04-22 | 282 | 25d | 0d | Traffic Design Engineer | 75h |
| 327 | 5.11 | **3RR1 Perform Railroad Coordination** | 1d? | 2026-04-09 | 2026-04-09 |  | 34d |  |  | 7.5h |
| 328 | 5.11.1 | 1.0 Receive Railroad Plans and Estimates | 1d? | 2026-04-09 | 2026-04-09 | 283 | 34d | 9d | Railroad Coordinator | 7.5h |
| 329 | 5.12 | **3RR2 Prepare and Submit Railroad Certification** | 270d | 2025-06-02 | 2026-07-06 |  | 49.87d |  |  | 2025h |
| 330 | 5.12.1 | 1.0 Finalize the Railroad Agreement(s) | 270d | 2025-06-02 | 2026-07-06 |  | 49.87d |  | Railroad Coordinator | 2025h |

Notes:
- 307: As soon as the ESCPs are available; application must include stamped cover sheet
- 313: This can tie to Line and Grade if Line and Grade includes survey of the ROW.
- 316: Duration will depend on number of acquisitions/relocations
- 317: Duration will depend on number of acquisitions/relocations
- 319: Duration will depend on number of acquisitions
- 320: Duration will depend on number of relocations
- 327: Tied currently to Plan-in-Hand Plans, but could tie to Functional Design Plans if coordinated with Railroad
- 328: Duration needs to be coordinated with Railroad
- 329: Tied currently to Plan-in-Hand Plans, but could tie to Functional Design Plans if coordinated with Railroad
- 330: Default duration that needs to be coordinated with Railroad. Also need to tie to the appropriate planset (either the Functional Resubmittal or PIH submittal)

| ID | WBS | Task | Type | Duration | Start | Finish | Predecessors | Total slack | Free slack | Resources | Work |
| --- | --- | --- | --- | --- | --- | --- | --- | --- | --- | --- | --- |
| 331 | 5.13 | **3PM2 Hold Plan-in-Hand Field Review Meeting** |  | 20d | 2026-04-30 | 2026-05-28 |  | 25d |  |  | 262.5h |
| 332 | 5.13.1 | 1.0 Review Period (Complete Comment Form) |  | 15d | 2026-04-30 | 2026-05-20 | 284 | 25d | 0d | TDOT Project Manager | 112.5h |
| 333 | 5.13.2 | 2.0 Quality Assurance Evaluation |  | 15d | 2026-04-30 | 2026-05-20 | 284 | 125d |  | Regional Quality Team Lead | 112.5h |
| 334 | 5.13.3 | 3.0 Compile Comments and Hold Meeting |  | 5d | 2026-05-21 | 2026-05-28 | 332 | 25d | 0d | TDOT Project Manager | 37.5h |
| 335 | 6 | Stage 3 Complete | milestone | 0d | 2026-05-28 | 2026-05-28 | 334 | 120d |  |  |  |
| 336 | 7 | **STAGE 4- PS&E** |  | 50d | 2026-05-29 | 2026-08-07 |  | 25d |  |  | 1275h |
| 337 | 7.1 | **4RD1 Finalize Construction Documents** |  | 35d | 2026-05-29 | 2026-07-17 |  | 25d |  |  | 262.5h |
| 338 | 7.1.1 | 1.0 Finalize the Roadway Plans for the PS&E Review Meeting |  | 20d | 2026-05-29 | 2026-06-26 | 334 | 25d | 0d | Roadway Design Lead | 150h |
| 339 | 7.1.2 | 2.0 Compile the Final Construction Documents |  | 15d | 2026-06-29 | 2026-07-17 | 338, 341, 342, 347, 348, 344, 345 | 25d | 0d | Roadway Design Lead | 112.5h |
| 340 | 7.2 | **4GT1 Finalize Geotech Plans** |  | 20d | 2026-05-29 | 2026-06-26 |  | 25d |  |  | 300h |
| 341 | 7.2.1 | 1.0 Finalize Geotechnical Design Documents |  | 20d | 2026-05-29 | 2026-06-26 | 334 | 25d | 0d | Lead Geotechnical Engineer/Geologist | 150h |
| 342 | 7.2.2 | 2.0 Finalize Geotechnical Special Provisions for Letting |  | 20d | 2026-05-29 | 2026-06-26 | 334 | 25d | 0d | Lead Geotechnical Engineer/Geologist | 150h |
| 343 | 7.3 | **4ST1 Finalize Structural Plans** |  | 20d | 2026-05-29 | 2026-06-26 |  | 25d |  |  | 300h |
| 344 | 7.3.1 | 1.0 Finalize Retaining/Noise Wall Plans |  | 20d | 2026-05-29 | 2026-06-26 | 334 | 25d | 0d | Structural Design Lead | 150h |
| 345 | 7.3.2 | 2.0 Finalize Bridge Plans |  | 20d | 2026-05-29 | 2026-06-26 | 334 | 25d | 0d | Structural Design Lead | 150h |
| 346 | 7.4 | **4TD1 Finalize Signal, Lighting, and ITS Plans** |  | 20d | 2026-05-29 | 2026-06-26 |  | 25d |  |  | 300h |
| 347 | 7.4.1 | 1.0 Finalize Related Design Documents |  | 20d | 2026-05-29 | 2026-06-26 | 334 | 25d | 0d | Traffic Design Engineer | 150h |
| 348 | 7.4.2 | 2.0 Finalize ITS Special Provisions |  | 20d | 2026-05-29 | 2026-06-26 | 334 | 25d | 0d | Traffic Design Engineer | 150h |
| 349 | 7.5 | **4PM2 Hold PS&E Review Meeting** |  | 15d | 2026-07-20 | 2026-08-07 |  | 25d |  |  | 112.5h |
| 350 | 7.5.1 | 1.0 Review and Complete Comment Form |  | 5d | 2026-07-20 | 2026-07-24 | 339 | 25d | 0d | TDOT Project Manager | 37.5h |
| 351 | 7.5.2 | 2.0 Compile Comments, Hold Meeting, and Finalize Project Documentation |  | 5d | 2026-07-27 | 2026-07-31 | 350 | 25d | 0d | TDOT Project Manager | 37.5h |
| 352 | 7.5.3 | 3.0 Finalize Project Documentation |  | 5d | 2026-08-03 | 2026-08-07 | 351 | 25d | 0d | TDOT Project Manager | 37.5h |
| 353 | 8 | Design Complete | milestone | 0d | 2026-08-07 | 2026-08-07 | 352 | 25d | 0d | Roadway Design Lead |  |
| 354 | 9 | Deadline to turn into the QA team |  | 10d | 2026-08-10 | 2026-08-21 | 353 | 60d |  | Regional Quality Team Lead | 75h |
| 355 | 10 | Construction Document Turn-in | milestone | 5d | 2026-09-15 | 2026-09-21 | 301, 248, 203, 298, 321, 253, 152, 308, 353, 330 | 0d |  | RTE | 37.5h |
| 356 | 11 | Stage 4 Complete | milestone | 0d | 2026-09-21 | 2026-09-21 | 355 | 40d |  |  |  |
| 357 | 12 | Project Letting | milestone | 40d | 2026-09-22 | 2026-11-17 | 355 | 0d |  |  |  |

Notes:
- 331: 4 weeks (20 working days) is default timing broken down as follows: / 1) 3 weeks for TDOT reviewers to complete their review and submit a completed Comment Resolution Form / 2) One week for design team to compile comments and prepare for meeting. / 3) Field review meeting to occur at the end of the 4 weeks/20 working days.
- 349: 2 weeks (10 working days) is default timing broken down as follows: / 1) 1 week for TDOT reviewers to complete their review and submit a completed Comment Resolution Form / 2) One week for design team to compile comments and prepare for meeting. / 3) Last review meeting to occur at the end of the 2 weeks/10 working days.
- 354: Final deliverable review
