# Project Schedule

Schedule from MS Project, 2021-06-16 to 2023-02-15.

## Calendars

- Standard: Mon-Fri 08:00-12:00, 13:00-17:00; Sat-Sun off.

## Resources

| Resource |
| --- |
| Kniazewycz |
| Cantrell |

## Schedule

| ID | WBS | Task | Type | Duration | Start | Finish | Predecessors | Total slack | Free slack |
| --- | --- | --- | --- | --- | --- | --- | --- | --- | --- |
| 1 | 1 | **STAGE 1- CONTEXT/SCOPING** |  | 72d? | 2021-06-16 | 2021-09-23 |  | 0d |  |
| 2 | 1.1 | **1PM1 Set Up Project** |  | 20d? | 2021-06-16 | 2021-07-13 |  | 0d |  |
| 3 | 1.1.1 | - Build Project Team (1PM2) |  | 1d? | 2021-06-16 | 2021-06-16 |  | 19d |  |
| 4 | 1.1.2 | - Develop Project Management Plan |  | 20d | 2021-06-16 | 2021-07-13 |  | 0d |  |
| 5 | 1.1.3 | - Prepare Draft Project Commitment Document (PCD) |  | 5d | 2021-06-16 | 2021-06-22 |  | 15d |  |
| 6 | 1.1.4 | - Request Authorization of Funds |  | 1d | 2021-06-16 | 2021-06-16 |  | 19d |  |
| 7 | 1.2 | **2PM1 Manage Project** |  | 20d? | 2021-07-14 | 2021-08-10 | 2 | 396d |  |
| 8 | 1.2.1 | **- Perform Quality Audits** |  | 5d | 2021-07-14 | 2021-07-20 |  | 411d |  |
| 9 | 1.2.1.1 | - Quality Audit 1 |  | 5d | 2021-07-14 | 2021-07-20 |  | 411d |  |
| 10 | 1.2.1.2 | - Quality Audit 2 |  | 5d | 2021-07-14 | 2021-07-20 |  | 411d |  |
| 11 | 1.2.2 | **- Report Project Status** |  | 5d | 2021-07-14 | 2021-07-20 |  | 411d |  |
| 12 | 1.2.2.1 | - Status Update 1 |  | 5d | 2021-07-14 | 2021-07-20 |  | 411d |  |
| 13 | 1.2.2.2 | - Status Update 2 |  | 5d | 2021-07-14 | 2021-07-20 |  | 411d |  |
| 14 | 1.2.3 | **- Develop Local Government Agreements** |  | 20d | 2021-07-14 | 2021-08-10 |  | 396d |  |
| 15 | 1.2.3.1 | - Enter Agreement 1 Name |  | 20d | 2021-07-14 | 2021-08-10 |  | 396d |  |
| 16 | 1.2.3.2 | - Enter Agreement 2 Name |  | 20d | 2021-07-14 | 2021-08-10 |  | 396d |  |
| 17 | 1.2.4 | - Perform Letting Readiness Assessment |  | 1d? | 2021-07-14 | 2021-07-14 |  | 415d |  |
| 18 | 1.3 | 1PM3 Hold Kickoff Meeting | milestone | 1d | 2021-07-14 | 2021-07-14 | 2 | -72d | 0d |
| 19 | 1.4 | **1PM4 Conduct Initial Risk Workshop** |  | 1d? | 2021-07-14 | 2021-07-14 | 2 | 415d |  |
| 20 | 1.4.1 | **- Develop Risk Register** |  | 1d? | 2021-07-14 | 2021-07-14 |  | 415d |  |
| 21 | 1.4.1.1 | - Risk Update 1 |  | 1d | 2021-07-14 | 2021-07-14 |  | 415d |  |
| 22 | 1.4.1.2 | - Risk Update 2 |  | 1d? | 2021-07-14 | 2021-07-14 |  | 415d |  |
| 23 | 1.5 | **1SY1 Conduct Design-Level Survey** |  | 15d | 2021-07-15 | 2021-08-04 | 18 | 32d | 0d |
| 24 | 1.5.1 | - Prepare the Ground Control for Aerial Survey |  | 5d | 2021-07-15 | 2021-07-21 |  | 44d |  |
| 25 | 1.5.2 | - Complete the Aerial Survey (may add Complete Lidar Survey) |  | 15d | 2021-07-15 | 2021-08-04 |  | 34d |  |
| 26 | 1.5.3 | - Set Control Ground Survey |  | 5d | 2021-07-15 | 2021-07-21 |  | 44d |  |
| 27 | 1.5.4 | - Conduct Survey Public Involvement and Ground Survey |  | 15d | 2021-07-15 | 2021-08-04 |  | 34d |  |
| 28 | 1.5.5 | - Incorporate SUE Request into Survey |  | 10d | 2021-07-15 | 2021-07-28 |  | 39d |  |

Notes:
- 18: Set date for kickoff meeting to establish the rest of the schedule

| ID | WBS | Task | Type | Duration | Start | Finish | Predecessors | Total slack | Free slack |
| --- | --- | --- | --- | --- | --- | --- | --- | --- | --- |
| 29 | 1.6 | **1RD1 Initiate Roadway Design** |  | 18d? | 2021-07-15 | 2021-08-09 | 18 | 32d | 0d |
| 30 | 1.6.1 | - Establish Project-Specific Design Criteria |  | 5d | 2021-07-15 | 2021-07-21 |  | 45d | 11d |
| 31 | 1.6.2 | - Determine Work Zone Significance |  | 5d | 2021-07-15 | 2021-07-21 |  | 45d |  |
| 32 | 1.6.3 | - Develop Line, Grade, and Cross Sections (Line and Grade Package) |  | 1d? | 2021-08-05 | 2021-08-05 | 23 | 34d |  |
| 33 | 1.6.4 | - Lead the Line and Grade Package Field Review |  | 2d | 2021-08-06 | 2021-08-09 | 32 | 32d |  |
| 34 | 1.7 | **1UT1 Begin Third-Party (Utilities & Railroad) Coordination** |  | 50d? | 2021-07-15 | 2021-09-22 | 18 | 0d |  |
| 35 | 1.7.1 | - Conduct Utility Coordination Kickoff Meeting |  | 1d? | 2021-07-15 | 2021-07-15 |  | 49d | 16d |
| 36 | 1.7.2 | - Make Initial Utility Contact |  | 50d | 2021-07-15 | 2021-09-22 |  | 0d |  |
| 37 | 1.7.3 | - Initiate Railroad Coordination | inactive | 20d | 2021-07-15 | 2021-08-11 |  | 30d |  |
| 38 | 1.8 | **1EN1 Complete Environmental Resource Identification** |  | 1d? | 2021-07-15 | 2021-07-15 | 18 | 58d | 17d |
| 39 | 1.8.1 | - Conduct Historic Preservation Study and Identify Historic Property Boundary(ies) |  | 1d? | 2021-07-15 | 2021-07-15 |  | 58d | 16d |
| 40 | 1.8.2 | - Conduct Archaeological Study (Phase One) and Identify Boundary(ies) for Potentially Eligible Archaeology Sites |  | 1d? | 2021-07-15 | 2021-07-15 |  | 58d | 16d |
| 41 | 1.8.3 | - Conduct Native American Coordination to Identify Consulting Parties |  | 1d? | 2021-07-15 | 2021-07-15 |  | 58d |  |
| 42 | 1.8.4 | - Conduct Ecology Study and Identify Ecology Site Boundaries (including shapefiles of features) |  | 1d? | 2021-07-15 | 2021-07-15 |  | 58d | 16d |
| 43 | 1.8.5 | - Conduct Air Quality Study |  | 1d? | 2021-07-15 | 2021-07-15 |  | 58d | 16d |
| 44 | 1.8.6 | - Conduct Noise Study to Identify Potential Noise Receptor Locations |  | 1d? | 2021-07-15 | 2021-07-15 |  | 58d | 16d |
| 45 | 1.8.7 | - Conduct Hazardous Materials Study to Identify Potential Sites |  | 1d? | 2021-07-15 | 2021-07-15 |  | 58d |  |
| 46 | 1.8.8 | - Conduct Preliminary Study to Identify Section 4(f) and Section 6(f) Resources |  | 1d? | 2021-07-15 | 2021-07-15 |  | 58d |  |
| 47 | 1.8.9 | - Completed Desktop Study (Traffic (STID), CSRP (ROW), Farmland, FEMA, EJ, Exiting Conditions, Environmental Commitments) Data Collection and Review |  | 1d? | 2021-07-15 | 2021-07-15 |  | 58d | 16d |
| 48 | 1.9 | **1GT1 Develop Geotechnical Work Plan** |  | 10d | 2021-07-15 | 2021-07-28 | 18 | 49d | 8d |
| 49 | 1.9.1 | - Gather Relevant Geotechnical Information |  | 5d | 2021-07-15 | 2021-07-21 |  | 54d |  |
| 50 | 1.9.2 | - Complete Project-Specific Geotechnical Investigation |  | 10d | 2021-07-15 | 2021-07-28 |  | 49d |  |
| 51 | 1.9.3 | - Identify Project Type and Potential Mitigation Strategies |  | 5d | 2021-07-15 | 2021-07-21 |  | 54d |  |
| 52 | 1.9.4 | - Develop Geotechnical Work Plan |  | 10d | 2021-07-15 | 2021-07-28 |  | 49d |  |

Notes:
- 32: Depends on size of the project, and can be run parallel with survey at risk.
- 37: Reactivate if railroad is present

| ID | WBS | Task | Type | Duration | Start | Finish | Predecessors | Total slack | Free slack |
| --- | --- | --- | --- | --- | --- | --- | --- | --- | --- |
| 53 | 1.10 | **1ST1 Complete Existing and No Structure Modeling** |  | 1d? | 2021-08-05 | 2021-08-05 | 18, 23 | 67d | 2d |
| 54 | 1.10.1 | - Hydraulically Model Existing and No Structure Conditions |  | 1d? | 2021-08-05 | 2021-08-05 |  | 67d |  |
| 55 | 1.11 | **1TO1 Validate Analysis and Determine Significance** |  | 20d | 2021-07-15 | 2021-08-11 | 18 | 39d | 0d |
| 56 | 1.11.1 | - Validate Traffic Analysis |  | 20d | 2021-07-15 | 2021-08-11 |  | 39d |  |
| 57 | 1.11.2 | - Determine Work Zone Significance |  | 5d | 2021-07-15 | 2021-07-21 |  | 54d |  |
| 58 | 1.11.3 | - Determine Incident Management Application |  | 5d | 2021-07-15 | 2021-07-21 |  | 54d |  |
| 59 | 1.12 | 1PM5 Hold Scoping Meeting and Site Review | milestone | 1d | 2021-09-23 | 2021-09-23 | 29, 34, 38, 48, 55 | 9d | 0d |
| 60 | 2 | **STAGE 2- FOOTPRINT ESTABLISHED** |  | 81d? | 2021-08-10 | 2021-11-30 |  | 32d |  |
| 61 | 2.1 | **2PM2 Complete Project Commitment Document (PCD)** |  | 10d | 2021-09-24 | 2021-10-07 | 59 | 354d |  |
| 62 | 2.1.1 | - Finalize Project Commitment Document (PCD) |  | 10d | 2021-09-24 | 2021-10-07 |  | 354d |  |
| 63 | 2.2 | **2PM3 Conduct ROW Strategy Meeting(s)** |  | 1d? | 2021-09-24 | 2021-09-24 | 59, 29 | 363d |  |
| 64 | 2.2.1 | - Conduct Site Review |  | 1d? | 2021-09-24 | 2021-09-24 |  | 363d |  |
| 65 | 2.3 | **2SY1 Complete SUE and Requested Staking** |  | 19d? | 2021-09-24 | 2021-10-20 | 29, 59, 34, 48 | 9d |  |
| 66 | 2.3.1 | - Incorporate SUE Level A and B Request into Survey |  | 10d | 2021-10-07 | 2021-10-20 | 71, 90 | 0d |  |
| 67 | 2.3.2 | - Stake Sounding Holes |  | 1d? | 2021-09-24 | 2021-09-24 |  | 199d |  |
| 68 | 2.3.3 | - Stake ROW |  | 1d? | 2021-09-24 | 2021-09-24 |  | 199d |  |
| 69 | 2.4 | **2RD1 Develop Functional Design Plans** |  | 62d? | 2021-08-10 | 2021-11-03 | 29 | 5d |  |
| 70 | 2.4.1 | - Develop a Utility Impact/Conflict Matrix |  | 10d | 2021-08-10 | 2021-08-23 | 35 | 57d |  |
| 71 | 2.4.2 | - Identify Initial Subsurface Utility Engineering (SUE) Needs |  | 5d | 2021-08-10 | 2021-08-16 | 29 | 37d |  |
| 72 | 2.4.3 | - Request Pavement Design |  | 1d? | 2021-08-10 | 2021-08-10 |  | 66d |  |
| 73 | 2.4.4 | - Document Design Exceptions |  | 1d | 2021-08-10 | 2021-08-10 | 30 | 66d |  |
| 74 | 2.4.5 | - Incorporate SUE Data and Lead Internal Design Deconfliction Meeting |  | 10d | 2021-10-21 | 2021-11-03 | 71, 90, 66 | 5d |  |
| 75 | 2.4.6 | - Develop Conceptual Traffic Control Strategies |  | 10d | 2021-08-10 | 2021-08-23 |  | 57d |  |
| 76 | 2.4.7 | - Develop Functional Design Plans |  | 1d? | 2021-08-10 | 2021-08-10 |  | 66d |  |
| 77 | 2.4.8 | - Coordinate Geotechnical Analysis for Noise and Retaining Walls |  | 5d | 2021-08-10 | 2021-08-16 |  | 62d |  |
| 78 | 2.4.9 | - Compile the Functional Design Plans for Field Review |  | 3d | 2021-08-10 | 2021-08-12 |  | 64d | 0d |

Notes:
- 64: Various (as many as needed)
- 70: Or use related line 91 under 2UT1
- 76: Depends on size of the project

| ID | WBS | Task | Type | Duration | Start | Finish | Predecessors | Total slack | Free slack |
| --- | --- | --- | --- | --- | --- | --- | --- | --- | --- |
| 79 | 2.5 | **2RD2 Conduct Design Public Meeting** |  | 25d | 2021-09-24 | 2021-10-28 | 29, 59 | 9d |  |
| 80 | 2.5.1 | - Prepare for the Design Public Meeting |  | 25d | 2021-09-24 | 2021-10-28 |  | 9d |  |
| 81 | 2.5.2 | - Hold Design Public Meeting | inactive | 1d | 2021-09-24 | 2021-09-24 |  | 33d |  |
| 82 | 2.5.3 | - Process Design Public Meeting Transcript | inactive | 10d | 2021-09-24 | 2021-10-07 |  | 24d |  |
| 83 | 2.6 | **2PV1 Provide Pavement Design** |  | 10d | 2021-08-17 | 2021-08-30 | 29, 48, 95 | 52d |  |
| 84 | 2.6.1 | - Provide Pavement Design |  | 10d | 2021-08-17 | 2021-08-30 |  | 52d |  |
| 85 | 2.7 | **2RW1 Initiate Pre-Acquisition Activities** |  | 5d? | 2021-08-10 | 2021-08-16 | 29 | 62d | 0d |
| 86 | 2.7.1 | - Prepare Right-of-Way Estimate |  | 5d | 2021-08-10 | 2021-08-16 |  | 62d |  |
| 87 | 2.7.2 | - Initiate PGI Field Work |  | 1d? | 2021-08-10 | 2021-08-10 |  | 66d |  |
| 88 | 2.7.3 | - Perform Title Searches |  | 1d? | 2021-08-10 | 2021-08-10 |  | 66d |  |
| 89 | 2.8 | **2UT1 Utility/Railroad Pre-Acquisition Activities** |  | 35d | 2021-09-23 | 2021-11-10 | 29, 34 | 0d |  |
| 90 | 2.8.1 | - Coordinate/Request Needed SUE |  | 10d | 2021-09-23 | 2021-10-06 |  | 0d |  |
| 91 | 2.8.2 | - Prepare Utility Estimate |  | 5d | 2021-09-23 | 2021-09-29 |  | 30d |  |
| 92 | 2.8.3 | - Prepare Railroad Estimates | inactive | 10d | 2021-09-23 | 2021-10-06 |  | 25d |  |
| 93 | 2.8.4 | - Develop a Utility Impact/Conflict Matrix |  | 10d | 2021-09-23 | 2021-10-06 |  | 25d |  |
| 94 | 2.8.5 | - Review SUE Data and Attend Internal Design Deconfliction Meeting |  | 15d | 2021-10-21 | 2021-11-10 | 71, 90, 66 | 0d |  |
| 95 | 2.9 | **2GT1 Complete the Soils and Geology Report** |  | 5d? | 2021-08-10 | 2021-08-16 | 29, 48 | 52d | 0d |
| 96 | 2.9.1 | - Conduct Site Exploration for Soils and Geology Report |  | 1d? | 2021-08-10 | 2021-08-10 |  | 56d |  |
| 97 | 2.9.2 | - Select the Appropriate Laboratory Testing Program |  | 5d | 2021-08-10 | 2021-08-16 |  | 52d |  |
| 98 | 2.9.3 | - Develop the Soils and Geology Report |  | 1d? | 2021-08-10 | 2021-08-10 |  | 56d |  |
| 99 | 2.9.4 | - Develop Associated Geotechnical Sheet (G-Sheets) |  | 1d? | 2021-08-10 | 2021-08-10 |  | 56d |  |
| 100 | 2.9.5 | - Develop Supporting Project Addenda |  | 1d? | 2021-08-10 | 2021-08-10 |  | 56d |  |
| 101 | 2.10 | **2GT2 Complete Soils/Foundation Reports** |  | 20d? | 2021-08-10 | 2021-09-06 | 29, 48 | 298d | 57d |
| 102 | 2.10.1 | - Conduct Site Exploration for Structures |  | 1d? | 2021-08-10 | 2021-08-10 |  | 317d |  |
| 103 | 2.10.2 | - Complete and Submit Foundation Report for Retaining Wall(s) |  | 20d | 2021-08-10 | 2021-09-06 |  | 298d |  |
| 104 | 2.10.3 | - Complete and Submit Foundation Report for Noise Wall(s) |  | 20d | 2021-08-10 | 2021-09-06 |  | 298d |  |
| 105 | 2.10.4 | - Complete and Submit Standard Report for Signs, Lighting, Signals, ITS, and High-Mast Lighting |  | 20d | 2021-08-10 | 2021-09-06 |  | 298d |  |
| 106 | 2.10.5 | - Complete and Submit Foundation Report for Bridges |  | 20d | 2021-08-10 | 2021-09-06 |  | 298d |  |

Notes:
- 81: Reactivate if applicable
- 82: Reactivate if applicable
- 87: Depends on size of project
- 88: Depends on size of project
- 90: Coordinate with Line 70
- 92: Reactivate if railroad is present
- 93: Or use related line 69 under 2RD1

| ID | WBS | Task | Duration | Start | Finish | Predecessors | Total slack | Free slack | Text1 |
| --- | --- | --- | --- | --- | --- | --- | --- | --- | --- |
| 107 | 2.11 | **2ST1 Complete Hydraulic Design** | 2d? | 2021-08-10 | 2021-08-11 | 29, 53 | 65d |  |  |
| 108 | 2.11.1 | - Verify Proposed Grade and Estimate Hydraulic Structure Sizes | 1d? | 2021-08-10 | 2021-08-10 |  | 66d |  |  |
| 109 | 2.11.2 | - Develop Draft Hydraulic Layout | 1d? | 2021-08-10 | 2021-08-10 |  | 65d | 0d |  |
| 110 | 2.11.3 | - Hydraulically Model Proposed Conditions, Evaluate Proposals, and Select Appropriate Structure | 1d? | 2021-08-10 | 2021-08-10 |  | 65d | 0d |  |
| 111 | 2.11.4 | - Finalize Hydraulic Layout | 1d? | 2021-08-11 | 2021-08-11 | 109, 110 | 65d |  |  |
| 112 | 2.11.5 | - Finalize Hydraulic Design Information | 1d? | 2021-08-11 | 2021-08-11 | 109, 110 | 65d |  |  |
| 113 | 2.12 | **2ST2 Develop Preliminary Bridge Plans** | 5d? | 2021-08-10 | 2021-08-16 | 29, 23 | 62d |  |  |
| 114 | 2.12.1 | - Review Proposed Grade and Alignment for Non-Hydraulic Crossings | 1d? | 2021-08-10 | 2021-08-10 |  | 66d |  |  |
| 115 | 2.12.2 | - Develop Preliminary Bridge Layouts | 1d? | 2021-08-10 | 2021-08-10 |  | 66d |  |  |
| 116 | 2.12.3 | - Coordinate Geotechnical Analysis for Bridges | 5d | 2021-08-10 | 2021-08-16 |  | 62d |  |  |
| 117 | 2.13 | **2EN1 Complete Environmental Resource Effects/Impacts** | 1d? | 2021-08-10 | 2021-08-10 | 38, 29 | 199d | 0d |  |
| 118 | 2.13.1 | - Complete Necessary Resource Effect/Impact Evaluations (all other resources) | 1d? | 2021-08-10 | 2021-08-10 | 47 | 199d |  |  |
| 119 | 2.13.2 | - Finalize Historic Preservation Effects Study | 1d? | 2021-08-10 | 2021-08-10 | 39 | 199d |  |  |
| 120 | 2.13.3 | - Finalize Phase Two Archaeological Eligibility Study | 1d? | 2021-08-10 | 2021-08-10 | 40 | 199d |  |  |
| 121 | 2.13.4 | - Finalize Air Quality Impact Study | 1d? | 2021-08-10 | 2021-08-10 | 43 | 199d |  |  |
| 122 | 2.13.5 | - Finalize Noise Abatement Study | 1d? | 2021-08-10 | 2021-08-10 | 44 | 199d | 76d |  |
| 123 | 2.13.6 | - Finalize Ecology Environmental Boundaries Report | 1d? | 2021-08-10 | 2021-08-10 | 42 | 199d |  |  |
| 124 | 2.13.7 | - Confirm Multimodal Compliance Determination | 1d? | 2021-08-10 | 2021-08-10 |  | 199d |  |  |
| 125 | 2.14 | **2EN2 Complete Environmental Document** | 80d? | 2021-08-11 | 2021-11-30 | 29, 117 | 129d | 0d |  |
| 126 | 2.14.1 | - Confirm Approval of Project in the STIP | 1d | 2021-08-11 | 2021-08-11 |  | 208d |  |  |
| 127 | 2.14.2 | - Complete Environmental Resource Agency Coordination | 1d? | 2021-08-11 | 2021-08-11 |  | 208d |  |  |
| 128 | 2.14.3 | - Review/Finalize Purpose and Need Statement | 10d | 2021-08-11 | 2021-08-24 |  | 199d |  |  |
| 129 | 2.14.4 | - Complete Environmental Document | 1d? | 2021-08-11 | 2021-08-11 |  | 208d |  |  |
| 130 | 2.14.5 | - Receive FHWA NEPA Approval (as applicable) | 10d | 2021-08-11 | 2021-08-24 |  | 199d |  |  |
| 131 | 2.14.6 | - Functional Design Plans Review (if needed): Complete Environmental Document Re-Evaluation | 1d? | 2021-08-13 | 2021-08-13 | 78 | 206d |  | Yes |
| 132 | 2.14.7 | - Plan-in-Hand Review: Complete Environmental Document Re-Evaluation | 1d? | 2021-11-30 | 2021-11-30 | 157 | 129d |  | Yes |

Notes:
- 120: If needed
- 129: Includes sending FHWA Notice of Intent
- 131: This could be 3 weeks to 6 months depending on impacts/changes in design. This activity is optional depending on if the environmental document is complete at the time the plans are submitted for review.
- 132: This could be 3 weeks to 6 months depending on impacts/changes in design.

| ID | WBS | Task | Type | Duration | Start | Finish | Predecessors | Total slack | Free slack |
| --- | --- | --- | --- | --- | --- | --- | --- | --- | --- |
| 133 | 2.15 | **2EN3 Conduct Permit Assessment** |  | 1d? | 2021-08-10 | 2021-08-10 | 29, 53, 42 | 66d | 0d |
| 134 | 2.15.1 | - Attend/Lead Permit Strategy Meeting (also see 2PM4) |  | 1d? | 2021-08-10 | 2021-08-10 |  | 66d |  |
| 135 | 2.15.2 | - Complete Permit Assessment, Redlined Plans, and Request for Permit Sketches |  | 1d? | 2021-08-10 | 2021-08-10 |  | 66d |  |
| 136 | 2.15.3 | - Lead Pre-application meeting with USACE and TDEC |  | 1d | 2021-08-10 | 2021-08-10 |  | 66d |  |
| 137 | 2.16 | **2EN4 Complete Mitigation Assessment and Initiate Mitigation Design** |  | 1d? | 2021-08-10 | 2021-08-10 | 29, 53, 42 | 66d |  |
| 138 | 2.16.1 | - Evaluate mitigation (Bank or In-Lieu fee) availability and permittee responsibilities |  | 1d? | 2021-08-10 | 2021-08-10 |  | 66d |  |
| 139 | 2.16.2 | - Complete Mitigation Assessment |  | 1d? | 2021-08-10 | 2021-08-10 |  | 66d |  |
| 140 | 2.16.3 | - Identify Need for Concurrent Project |  | 1d? | 2021-08-10 | 2021-08-10 |  | 66d |  |
| 141 | 2.16.4 | - Develop Preliminary Mitigation Plan (30% designed) |  | 1d? | 2021-08-10 | 2021-08-10 |  | 66d |  |
| 142 | 2.17 | **2TO1 Prepare ITS, Signals, and Lighting Sheets** |  | 1d? | 2021-08-12 | 2021-08-12 | 29, 55 | 64d |  |
| 143 | 2.17.1 | - Prepare TSMO/ITS Device Sheets |  | 1d? | 2021-08-12 | 2021-08-12 |  | 64d |  |
| 144 | 2.17.2 | - Prepare Signal Sheets | inactive | 1d | 2021-08-12 | 2021-08-12 |  | 64d |  |
| 145 | 2.17.3 | - Prepare Lighting Sheets |  | 1d? | 2021-08-12 | 2021-08-12 |  | 64d |  |
| 146 | 2.17.4 | - Oversee Development of the Conceptual Traffic Control Strategies |  | 1d? | 2021-08-12 | 2021-08-12 |  | 64d |  |
| 147 | 2.18 | 2PM4 Conduct Permit Strategy Meeting(s) | milestone | 1d | 2021-08-10 | 2021-08-10 | 23, 29, 38 | 396d |  |
| 148 | 2.19 | **2PM5 Hold Functional Design Plans Field Review Meeting** |  | 10d | 2021-11-11 | 2021-11-24 | 69, 79, 83, 85, 89, 95, 107, 113, 133, 137, 142 | 0d |  |
| 149 | 2.19.1 | - Hold Meeting and Document/Distribute Minutes |  | 10d | 2021-11-11 | 2021-11-24 |  | 0d |  |
| 150 | 3 | **STAGE 3- PLAN-IN-HAND** |  | 341d? | 2021-08-11 | 2022-11-30 |  | 0d |  |
| 151 | 3.1 | **3RD1 Complete Plan-in-Hand Design** |  | 5d? | 2021-11-25 | 2021-12-01 | 148 | 0d |  |
| 152 | 3.1.1 | - Develop ROW Acquisition Exhibits |  | 1d? | 2021-11-25 | 2021-11-25 |  | 241d |  |
| 153 | 3.1.2 | - Develop Utility Coordination Plans |  | 1d? | 2021-11-25 | 2021-11-25 |  | 241d |  |
| 154 | 3.1.3 | - Develop Design and Sketches for Permit Applications |  | 1d? | 2021-11-25 | 2021-11-25 |  | 0d |  |
| 155 | 3.1.4 | - Finalize the TMP & Complete the Temporary Traffic Control Plans |  | 5d | 2021-11-25 | 2021-12-01 |  | 237d |  |
| 156 | 3.1.5 | - Complete Plan-in-Hand Plans |  | 1d? | 2021-11-25 | 2021-11-25 |  | 241d |  |
| 157 | 3.1.6 | - Compile the Plan-in-Hand Plans for Field Review |  | 3d | 2021-11-25 | 2021-11-29 |  | 129d | 0d |

Notes:
- 134: Re-occurring meeting among design (roadway, structures), utilities, ROW, mitigation, permitting, and others to coordinate on permit application requirements.
- 135: Depends on size of project
- 136: Optional task that will help in coordinating with USACE and TDEC on the project details and upcoming permit application and content.
- 147: Re-occurring meeting among design (roadway, structures), utilities, ROW, mitigation, permitting, and others to coordinate on permit application requirements.
- 152: This could begin in Stage 2.
- 153: This could begin in Stage 2.
- 154: This could begin in Stage 2.

| ID | WBS | Task | Type | Duration | Start | Finish | Predecessors | Total slack | Free slack |
| --- | --- | --- | --- | --- | --- | --- | --- | --- | --- |
| 158 | 3.2 | **3UT1 Perform Utility Coordination** |  | 86d? | 2021-11-11 | 2022-03-10 | 65, 89 | 166d | 0d |
| 159 | 3.2.1 | - Process Consultant Requests |  | 5d | 2021-11-11 | 2021-11-17 |  | 247d |  |
| 160 | 3.2.2 | - Send Utility Coordination Plans |  | 5d | 2021-11-11 | 2021-11-17 |  | 207d | 0d |
| 161 | 3.2.3 | - Conduct Utility Plan Review Kickoff Meeting |  | 1d? | 2021-11-11 | 2021-11-11 |  | 251d |  |
| 162 | 3.2.4 | - 60-Day Deconfliction Meeting |  | 40d | 2021-11-18 | 2022-01-12 | 160 | 207d |  |
| 163 | 3.2.5 | - Process Relocation Contract Requests |  | 5d | 2021-11-11 | 2021-11-17 |  | 247d |  |
| 164 | 3.2.6 | - Complete 120-day Utility Review and Submit Rainbows to Environmental |  | 86d | 2021-11-11 | 2022-03-10 |  | 166d |  |
| 165 | 3.2.7 | - Put Utilities to Work |  | 10d | 2021-11-11 | 2021-11-24 |  | 242d |  |
| 166 | 3.2.8 | - Submit Construction Drawings to Design |  | 5d | 2021-11-11 | 2021-11-17 |  | 247d |  |
| 167 | 3.3 | **3UT2 Perform Railroad Coordination** |  | 0d? | 2021-11-10 | 2021-11-10 | 89 | 252d | 86d |
| 168 | 3.3.1 | - Receive Railroad Plans and Estimates | inactive | 270d | 2021-11-11 | 2022-11-23 |  | -18d | 0d |
| 169 | 3.4 | **3UT3 Prepare and Submit Utility/Railroad Certification** |  | 10d | 2022-03-11 | 2022-03-24 | 158, 167 | 179d |  |
| 170 | 3.4.1 | - Receive and Process Utility Deposits |  | 10d | 2022-03-11 | 2022-03-24 |  | 179d |  |
| 171 | 3.4.2 | - Verify Utility Coordination is Complete |  | 5d | 2022-03-11 | 2022-03-17 |  | 184d |  |
| 172 | 3.4.3 | - Finalize Railroad Agreement(s) | inactive | 20d | 2022-03-11 | 2022-04-07 |  | 169d |  |
| 173 | 3.5 | **3EN1 Finalize Stream & Wetland Mitigation Design** |  | 1d? | 2021-11-25 | 2021-11-25 | 148, 137 | 241d | 75d |
| 174 | 3.5.1 | - Finalize Mitigation Plans |  | 1d? | 2021-11-25 | 2021-11-25 |  | 241d |  |
| 175 | 3.6 | **3EN2 Complete Environmental Permit Applications and Obtain Permits** |  | 341d | 2021-08-11 | 2022-11-30 | 133 | 0d |  |
| 176 | 3.6.1 | - Complete Stormwater Permit Application |  | 10d | 2021-08-11 | 2021-08-24 |  | 301d | 0d |
| 177 | 3.6.2 | - Complete Aquatic Permit Applications |  | 40d | 2021-11-26 | 2022-01-20 | 141, 154, 133 | 0d |  |
| 178 | 3.6.3 | **- Obtain Aquatic Resource Permits** |  | 224d | 2022-01-21 | 2022-11-30 |  | 0d |  |
| 179 | 3.6.3.1 | - 45 day Agency review |  | 32d | 2022-01-21 | 2022-03-07 | 177 | 0d |  |
| 180 | 3.6.3.2 | - 30 days TDOT response to RFI/RAI and incorporate utilities (if needed) |  | 20d | 2022-03-08 | 2022-04-04 | 179 | 0d |  |
| 181 | 3.6.3.3 | - 30 days Agency Review |  | 20d | 2022-04-05 | 2022-05-02 | 180 | 0d |  |
| 182 | 3.6.3.4 | - 30 days TDOT response to RFI/RAI |  | 20d | 2022-05-03 | 2022-05-30 | 181 | 0d |  |
| 183 | 3.6.3.5 | - 45 days for drafting permit |  | 32d | 2022-05-31 | 2022-07-13 | 182, 125 | 0d |  |
| 184 | 3.6.3.6 | - 30 day public notice |  | 20d | 2022-07-14 | 2022-08-10 | 183 | 0d |  |
| 185 | 3.6.3.7 | - 90 day request for hearing (if needed) |  | 60d | 2022-08-11 | 2022-11-02 | 184 | 0d |  |
| 186 | 3.6.3.8 | - USACE to send to EPA for final review |  | 10d | 2022-11-03 | 2022-11-16 | 185 | 0d |  |
| 187 | 3.6.3.9 | - USACE issues the permit |  | 10d | 2022-11-17 | 2022-11-30 | 186 | 0d |  |
| 188 | 3.6.4 | - Obtain NPDES Coverage |  | 30d | 2021-08-25 | 2021-10-05 | 176 | 301d |  |

Notes:
- 168: Reactivate if railroad is present. Default duration that needs to be coordinated with Railroad
- 170: Reactivate if railroad is present
- 171: Reactivate if railroad is present
- 172: Reactivate if railroad is present. Default duration needs to be coordinated with railroad
- 178: Activity logic and conservative durations included herein. These include durations for TDEC.
- 183: The logic tie to Complete the Environmental Document (Activity #124) is optional. If the document is complete, USACE can "adopt" TDOT document, which saves some time in the permitting process. If the document is not complete, then all environmental technical studies should be completed and included at the time of submitting the Aquatic Permit Applications (Activity #175).

| ID | WBS | Task | Type | Duration | Start | Finish | Predecessors | Total slack | Free slack |
| --- | --- | --- | --- | --- | --- | --- | --- | --- | --- |
| 189 | 3.7 | **3ST1 Complete Structural Design** |  | 1d? | 2021-11-25 | 2021-11-25 | 148, 65, 101 | 241d | 75d |
| 190 | 3.7.1 | - Complete Retaining/Noise Wall Sheets |  | 1d? | 2021-11-25 | 2021-11-25 | 122 | 241d |  |
| 191 | 3.7.2 | - Complete Design and Detail Bridge Plans and Estimate |  | 1d? | 2021-11-25 | 2021-11-25 |  | 241d |  |
| 192 | 3.8 | **3RW1 Complete Appraisal and Initiate Acquisition** |  | 30d? | 2021-08-17 | 2021-09-27 | 85, 29 | 297d | 46d |
| 193 | 3.8.1 | - Produce Preliminary Group Inspection (PGI) Report |  | 1d? | 2021-08-17 | 2021-08-17 |  | 326d |  |
| 194 | 3.8.2 | - Initiate Private Property Owner Utility Adjustment |  | 1d? | 2021-08-17 | 2021-08-17 |  | 326d |  |
| 195 | 3.8.3 | - Employ Fee Appraiser |  | 30d | 2021-08-17 | 2021-09-27 |  | 297d |  |
| 196 | 3.8.4 | - Appraise Property |  | 1d? | 2021-08-17 | 2021-08-17 |  | 326d |  |
| 197 | 3.8.5 | - Review Appraisals |  | 1d? | 2021-08-17 | 2021-08-17 |  | 326d |  |
| 198 | 3.9 | **3RW2 Execute ROW Proposal** |  | 0d? | 2021-11-24 | 2021-11-24 | 148 | 265d |  |
| 199 | 3.9.1 | - Prepare/Submit ROW Proposal | inactive | 1d? | 2021-11-25 | 2021-11-25 |  | 264d |  |
| 200 | 3.9.2 | - Receive ROW Proposal and Distribute for Execution | inactive | 1d? | 2021-11-25 | 2021-11-25 |  | 264d |  |
| 201 | 3.10 | **3RW3 Prepare and Submit ROW Certification** |  | 10d? | 2021-12-01 | 2021-12-14 | 125, 192 | 251d |  |
| 202 | 3.10.1 | - Perform/Finish Acquiring Property |  | 1d? | 2021-12-01 | 2021-12-01 |  | 260d |  |
| 203 | 3.10.2 | - Perform/Finish ROW Relocation |  | 1d? | 2021-12-01 | 2021-12-01 |  | 260d |  |
| 204 | 3.10.3 | - Review ROW Acquisition Process, Verify/Update Schedule, and Issue ROW Certification |  | 10d | 2021-12-01 | 2021-12-14 |  | 251d |  |
| 205 | 3.11 | **3TO1 Complete Signal, Lighting, and TSMO/ITS Device Design** |  | 1d? | 2021-11-25 | 2021-11-25 | 148, 101, 65 | 241d | 75d |
| 206 | 3.11.1 | - Complete Signal Design | inactive | 1d? | 2021-11-25 | 2021-11-25 |  | 241d |  |
| 207 | 3.11.2 | - Complete Lighting Design |  | 1d? | 2021-11-25 | 2021-11-25 |  | 241d |  |
| 208 | 3.11.3 | - Complete TSMO/ITS Device Design |  | 1d? | 2021-11-25 | 2021-11-25 |  | 241d |  |
| 209 | 3.11.4 | - Review the TMP for Compliance |  | 1d? | 2021-11-25 | 2021-11-25 |  | 241d |  |
| 210 | 3.12 | **3PM2 Hold Plan-in-Hand Field Review Meeting** |  | 10d | 2022-03-11 | 2022-03-24 | 151, 158, 167, 173, 189, 205 | 166d | 0d |
| 211 | 3.12.1 | - Hold Meeting and Document/Distribute Minutes |  | 10d | 2022-03-11 | 2022-03-24 |  | 166d |  |
| 212 | 4 | **STAGE 4- PS&E** |  | 13d? | 2022-03-25 | 2022-04-12 |  | 166d |  |
| 213 | 4.1 | **4RD1 Finalize Construction Documents** |  | 3d? | 2022-03-25 | 2022-03-29 | 210 | 166d | 0d |
| 214 | 4.1.1 | - Finalize the Roadway Plans for the PS&E Review Meeting |  | 1d? | 2022-03-25 | 2022-03-25 |  | 168d |  |
| 215 | 4.1.2 | - Compile the Final Construction Documents |  | 3d | 2022-03-25 | 2022-03-29 |  | 166d |  |

Notes:
- 196: Depends on number of acquisitions/relocations
- 197: Depends on number of acquisitions/relocations
- 202: Depends on number of acquisitions/relocations
- 203: Depends on number of acquisitions/relocations

| ID | WBS | Task | Type | Duration | Start | Finish | Predecessors | Total slack | Free slack |
| --- | --- | --- | --- | --- | --- | --- | --- | --- | --- |
| 216 | 4.2 | **4GT1 Finalize Geotech Plans** |  | 1d? | 2022-03-25 | 2022-03-25 | 210, 95, 101 | 168d | 2d |
| 217 | 4.2.1 | - Finalize Geotechnical Design Documents |  | 1d? | 2022-03-25 | 2022-03-25 |  | 168d |  |
| 218 | 4.2.2 | - Finalize Geotechnical Special Provisions for Letting |  | 1d? | 2022-03-25 | 2022-03-25 |  | 168d |  |
| 219 | 4.3 | **4ST1 Finalize Structural Plans** |  | 1d? | 2022-03-25 | 2022-03-25 | 210 | 168d | 2d |
| 220 | 4.3.1 | - Finalize Retaining/Noise Wall Plans |  | 1d? | 2022-03-25 | 2022-03-25 |  | 168d |  |
| 221 | 4.3.2 | - Finalize Bridge Plans |  | 1d? | 2022-03-25 | 2022-03-25 |  | 168d |  |
| 222 | 4.4 | **4TO1 Finalize Signal, Lighting, and TSMO/ITS Plans** |  | 1d? | 2022-03-25 | 2022-03-25 | 210 | 168d | 2d |
| 223 | 4.4.1 | - Finalize Signals, Lighting, and TSMO/ITS Design Documents |  | 1d? | 2022-03-25 | 2022-03-25 |  | 168d |  |
| 224 | 4.4.2 | - Finalize ITS Special Provisions for Letting |  | 1d? | 2022-03-25 | 2022-03-25 |  | 168d |  |
| 225 | 4.5 | **4PM2 Hold PS&E Review Meeting** |  | 10d | 2022-03-30 | 2022-04-12 | 213, 216, 219, 222 | 166d |  |
| 226 | 4.5.1 | - Hold Meeting and Document/Distribute Minutes |  | 10d | 2022-03-30 | 2022-04-12 |  | 166d |  |
| 227 | 5 | Construction Document Turn-in | milestone | 5d | 2022-12-01 | 2022-12-07 | 169, 175, 225, 198, 201, 125 | 0d |  |
| 228 | 6 | Project Letting | milestone | 50d | 2022-12-08 | 2023-02-15 | 227 | 0d |  |
