# Project Schedule- Widening, New Alignment, Interchange and Intersection

Schedule from MS Project, 2021-06-16 to 2022-12-01.

## Calendars

- Standard: Mon-Fri 08:00-12:00, 13:00-17:00; Sat-Sun off.

## Resources

| Resource |
| --- |
| Kniazewycz |
| Cantrell |

## Schedule

| ID | WBS | Task | Type | Duration | Start | Finish | Predecessors | Total slack | Free slack |
| --- | --- | --- | --- | --- | --- | --- | --- | --- | --- |
| 1 | 1 | **STAGE 1- CONTEXT/SCOPING** |  | 72d? | 2021-06-16 | 2021-09-23 |  | 0d |  |
| 2 | 1.1 | **1PM1 Set Up Project** |  | 20d? | 2021-06-16 | 2021-07-13 |  | 0d |  |
| 3 | 1.1.1 | - Build Project Team (1PM2) |  | 1d? | 2021-06-16 | 2021-06-16 |  | 19d |  |
| 4 | 1.1.2 | - Develop Project Management Plan |  | 20d | 2021-06-16 | 2021-07-13 |  | 0d |  |
| 5 | 1.1.3 | - Prepare Draft Project Commitment Document (PCD) |  | 5d | 2021-06-16 | 2021-06-22 |  | 15d |  |
| 6 | 1.1.4 | - Request Authorization of Funds |  | 1d | 2021-06-16 | 2021-06-16 |  | 19d |  |
| 7 | 1.2 | **2PM1 Manage Project** |  | 20d? | 2021-07-14 | 2021-08-10 | 2 | 223d |  |
| 8 | 1.2.1 | **- Perform Quality Audits** |  | 5d | 2021-07-14 | 2021-07-20 |  | 238d |  |
| 9 | 1.2.1.1 | - Quality Audit 1 |  | 5d | 2021-07-14 | 2021-07-20 |  | 457d |  |
| 10 | 1.2.1.2 | - Quality Audit 2 |  | 5d | 2021-07-14 | 2021-07-20 |  | 457d |  |
| 11 | 1.2.2 | **- Report Project Status** |  | 5d | 2021-07-14 | 2021-07-20 |  | 238d |  |
| 12 | 1.2.2.1 | - Status Update 1 |  | 5d | 2021-07-14 | 2021-07-20 |  | 457d |  |
| 13 | 1.2.2.2 | - Status Update 2 |  | 5d | 2021-07-14 | 2021-07-20 |  | 457d |  |
| 14 | 1.2.3 | **- Develop Local Government Agreements** |  | 20d | 2021-07-14 | 2021-08-10 |  | 223d |  |
| 15 | 1.2.3.1 | - Enter Agreement 1 Name |  | 20d | 2021-07-14 | 2021-08-10 |  | 442d |  |
| 16 | 1.2.3.2 | - Enter Agreement 2 Name |  | 20d | 2021-07-14 | 2021-08-10 |  | 442d |  |
| 17 | 1.2.4 | - Perform Letting Readiness Assessment |  | 1d? | 2021-07-14 | 2021-07-14 |  | 461d |  |
| 18 | 1.3 | 1PM3 Hold Kickoff Meeting | milestone | 1d | 2021-07-14 | 2021-07-14 | 2 | 0d |  |
| 19 | 1.4 | **1PM4 Conduct Initial Risk Workshop** |  | 1d | 2021-07-14 | 2021-07-14 | 2 | 242d |  |
| 20 | 1.4.1 | **- Develop Risk Register** |  | 1d | 2021-07-14 | 2021-07-14 |  | 242d |  |
| 21 | 1.4.1.1 | - Risk Update 1 |  | 1d | 2021-07-14 | 2021-07-14 |  | 461d |  |
| 22 | 1.4.1.2 | - Risk Update 2 |  | 1d | 2021-07-14 | 2021-07-14 |  | 461d |  |
| 23 | 1.5 | **1SY1 Conduct Design-Level Survey** |  | 10d | 2021-07-15 | 2021-07-28 | 18 | 37d | 0d |
| 24 | 1.5.1 | - Prepare the Ground Control for Aerial Survey | inactive | 10d | 2021-07-15 | 2021-07-28 |  | 39d |  |
| 25 | 1.5.2 | - Complete the Aerial Survey (may add Complete Lidar Survey) | inactive | 25d | 2021-07-15 | 2021-08-18 |  | 24d |  |
| 26 | 1.5.3 | - Set Control Ground Survey |  | 5d | 2021-07-15 | 2021-07-21 |  | 44d |  |
| 27 | 1.5.4 | - Conduct Survey Public Involvement and Ground Survey |  | 10d | 2021-07-15 | 2021-07-28 |  | 39d |  |
| 28 | 1.5.5 | - Incorporate SUE Request into Survey |  | 10d | 2021-07-15 | 2021-07-28 |  | 39d |  |

Notes:
- 18: Set date for kickoff meeting to establish the rest of the schedule

| ID | WBS | Task | Type | Duration | Start | Finish | Predecessors | Total slack | Free slack |
| --- | --- | --- | --- | --- | --- | --- | --- | --- | --- |
| 29 | 1.6 | **1RD1 Initiate Roadway Design** |  | 13d? | 2021-07-15 | 2021-08-02 | 18 | 37d | 0d |
| 30 | 1.6.1 | - Establish Project-Specific Design Criteria | inactive | 5d | 2021-07-15 | 2021-07-21 |  | 45d | 8d |
| 31 | 1.6.2 | - Determine Work Zone Significance |  | 5d | 2021-07-15 | 2021-07-21 |  | 45d |  |
| 32 | 1.6.3 | - Develop Line, Grade, and Cross Sections (Line and Grade Package) |  | 1d? | 2021-07-29 | 2021-07-29 | 23 | 39d |  |
| 33 | 1.6.4 | - Compile the Line and Grade Package for Field Review |  | 2d | 2021-07-30 | 2021-08-02 | 32 | 37d |  |
| 34 | 1.7 | **1UT1 Begin Third-Party (Utilities & Railroad) Coordination** |  | 50d | 2021-07-15 | 2021-09-22 | 18 | 0d |  |
| 35 | 1.7.1 | - Conduct Utility Coordination Kickoff Meeting |  | 1d | 2021-07-15 | 2021-07-15 |  | 49d | 12d |
| 36 | 1.7.2 | - Make Initial Utility Contact |  | 50d | 2021-07-15 | 2021-09-22 |  | 0d |  |
| 37 | 1.7.3 | - Initiate Railroad Coordination | inactive | 20d | 2021-07-15 | 2021-08-11 |  | 30d |  |
| 38 | 1.8 | **1EN1 Complete Environmental Resource Identification** |  | 1d? | 2021-07-15 | 2021-07-15 | 18 | 58d | 12d |
| 39 | 1.8.1 | - Conduct Historic Preservation Study and Identify Historic Property Boundary(ies) |  | 1d? | 2021-07-15 | 2021-07-15 |  | 58d | 12d |
| 40 | 1.8.2 | - Conduct Archaeological Study (Phase One) and Identify Boundary(ies) for Potentially Eligible Archaeology Sites |  | 1d? | 2021-07-15 | 2021-07-15 |  | 58d | 12d |
| 41 | 1.8.3 | - Conduct Native American Coordination to Identify Consulting Parties |  | 1d? | 2021-07-15 | 2021-07-15 |  | 58d |  |
| 42 | 1.8.4 | - Conduct Ecology Study and Identify Ecology Site Boundaries (including shapefiles of features) |  | 1d? | 2021-07-15 | 2021-07-15 |  | 58d | 12d |
| 43 | 1.8.5 | - Conduct Air Quality Study |  | 1d? | 2021-07-15 | 2021-07-15 |  | 58d | 12d |
| 44 | 1.8.6 | - Conduct Noise Study to Identify Potential Noise Receptor Locations |  | 1d? | 2021-07-15 | 2021-07-15 |  | 58d | 12d |
| 45 | 1.8.7 | - Conduct Hazardous Materials Study to Identify Potential Sites |  | 1d? | 2021-07-15 | 2021-07-15 |  | 58d |  |
| 46 | 1.8.8 | - Conduct Preliminary Study to Identify Section 4(f) and Section 6(f) Resources |  | 1d? | 2021-07-15 | 2021-07-15 |  | 58d |  |
| 47 | 1.8.9 | - Completed Desktop Study (Traffic (STID), CSRP (ROW), Farmland, FEMA, EJ, Exiting Conditions, Environmental Commitments) Data Collection and Review |  | 1d? | 2021-07-15 | 2021-07-15 |  | 58d | 12d |
| 48 | 1.9 | **1GT1 Develop Geotechnical Work Plan** |  | 10d | 2021-07-15 | 2021-07-28 | 18 | 49d | 3d |
| 49 | 1.9.1 | - Gather Relevant Geotechnical Information |  | 5d | 2021-07-15 | 2021-07-21 |  | 54d |  |
| 50 | 1.9.2 | - Complete Project-Specific Geotechnical Investigation | inactive | 10d | 2021-07-15 | 2021-07-28 |  | 49d |  |
| 51 | 1.9.3 | - Identify Project Type and Potential Mitigation Strategies | inactive | 5d | 2021-07-15 | 2021-07-21 |  | 54d |  |
| 52 | 1.9.4 | - Develop Geotechnical Work Plan |  | 10d | 2021-07-15 | 2021-07-28 |  | 49d |  |

Notes:
- 32: Duration depends on size of the project/complexity of design, and can be run parallel with survey at risk.
- 49: If applicable for signal and safety projects
- 52: If applicable for signal and safety projects

| ID | WBS | Task | Type | Duration | Start | Finish | Predecessors | Total slack | Free slack |
| --- | --- | --- | --- | --- | --- | --- | --- | --- | --- |
| 53 | 1.10 | **1ST1 Complete Existing and No Structure Modeling** |  | 0d? | 2021-07-28 | 2021-07-28 | 18, 23 | 137d | 3d |
| 54 | 1.10.1 | - Hydraulically Model Existing and No Structure Conditions | inactive | 1d? | 2021-07-29 | 2021-07-29 |  | 136d |  |
| 55 | 1.11 | **1TO1 Validate Analysis and Determine Significance** |  | 20d | 2021-07-15 | 2021-08-11 | 18 | 39d | 0d |
| 56 | 1.11.1 | - Validate Traffic Analysis |  | 20d | 2021-07-15 | 2021-08-11 |  | 39d |  |
| 57 | 1.11.2 | - Determine Work Zone Significance |  | 5d | 2021-07-15 | 2021-07-21 |  | 54d |  |
| 58 | 1.11.3 | - Determine Incident Management Application |  | 5d | 2021-07-15 | 2021-07-21 |  | 54d |  |
| 59 | 1.12 | 1PM5 Hold Scoping Meeting and Site Review | milestone | 1d | 2021-09-23 | 2021-09-23 | 29, 34, 38, 48, 55 | 9d | 0d |
| 60 | 2 | **STAGE 2- FOOTPRINT ESTABLISHED** |  | 81d? | 2021-08-02 | 2021-11-23 |  | 37d |  |
| 61 | 2.1 | **2PM2 Complete Project Commitment Document (PCD)** |  | 10d | 2021-09-24 | 2021-10-07 | 59 | 181d |  |
| 62 | 2.1.1 | - Finalize Project Commitment Document (PCD) |  | 10d | 2021-09-24 | 2021-10-07 |  | 181d |  |
| 63 | 2.2 | **2PM3 Conduct ROW Strategy Meeting(s)** |  | 1d? | 2021-09-24 | 2021-09-24 | 59, 29 | 190d |  |
| 64 | 2.2.1 | - Conduct Site Review |  | 1d? | 2021-09-24 | 2021-09-24 |  | 190d |  |
| 65 | 2.3 | **2SY1 Complete SUE and Requested Staking** |  | 19d? | 2021-09-24 | 2021-10-20 | 29, 59, 34, 48 | 9d |  |
| 66 | 2.3.1 | - Incorporate SUE Level A and B Request into Survey |  | 10d | 2021-10-07 | 2021-10-20 | 71, 90 | 0d |  |
| 67 | 2.3.2 | - Stake Sounding Holes |  | 1d? | 2021-09-24 | 2021-09-24 |  | 28d |  |
| 68 | 2.3.3 | - Stake ROW |  | 1d? | 2021-09-24 | 2021-09-24 |  | 28d |  |
| 69 | 2.4 | **2RD1 Develop Functional Design Plans** |  | 62d? | 2021-08-03 | 2021-10-27 | 29 | 42d | 5d |
| 70 | 2.4.1 | - Develop a Utility Impact/Conflict Matrix |  | 10d | 2021-08-03 | 2021-08-16 | 35 | 126d |  |
| 71 | 2.4.2 | - Identify Initial Subsurface Utility Engineering (SUE) Needs |  | 5d | 2021-08-03 | 2021-08-09 | 29 | 42d |  |
| 72 | 2.4.3 | - Request Pavement Design |  | 1d | 2021-08-03 | 2021-08-03 |  | 135d |  |
| 73 | 2.4.4 | - Document Design Exceptions |  | 1d | 2021-08-03 | 2021-08-03 | 30 | 135d |  |
| 74 | 2.4.5 | - Incorporate SUE Data and Lead Internal Design Deconfliction Meeting |  | 5d | 2021-10-21 | 2021-10-27 | 71, 90, 66 | 74d |  |
| 75 | 2.4.6 | - Develop Conceptual Traffic Control Strategies |  | 5d | 2021-08-03 | 2021-08-09 |  | 131d |  |
| 76 | 2.4.7 | - Develop Functional Design Plans |  | 1d? | 2021-08-03 | 2021-08-03 |  | 135d |  |
| 77 | 2.4.8 | - Coordinate Geotechnical Analysis for Noise and Retaining Walls | inactive | 5d | 2021-08-03 | 2021-08-09 |  | 131d |  |
| 78 | 2.4.9 | - Compile the Functional Design Plans for Field Review |  | 3d | 2021-08-03 | 2021-08-05 |  | 133d | 0d |

Notes:
- 64: Various (as many as needed)
- 70: Or use related line 91 under 2UT1
- 76: Duration depends on size of the project/complexity of design

| ID | WBS | Task | Type | Duration | Start | Finish | Predecessors | Total slack | Free slack |
| --- | --- | --- | --- | --- | --- | --- | --- | --- | --- |
| 79 | 2.5 | **2RD2 Conduct Design Public Meeting** |  | 0d | 2021-09-23 | 2021-09-23 | 29, 59 | 98d | 29d |
| 80 | 2.5.1 | - Prepare for the Design Public Meeting | inactive | 25d | 2021-09-24 | 2021-10-28 |  | 73d |  |
| 81 | 2.5.2 | - Hold Design Public Meeting | inactive | 1d | 2021-09-24 | 2021-09-24 |  | 97d |  |
| 82 | 2.5.3 | - Process Design Public Meeting Transcript | inactive | 10d | 2021-09-24 | 2021-10-07 |  | 88d |  |
| 83 | 2.6 | **2PV1 Provide Pavement Design** |  | 10d | 2021-08-03 | 2021-08-16 | 29, 48, 95 | 126d | 57d |
| 84 | 2.6.1 | - Provide Pavement Design |  | 10d | 2021-08-03 | 2021-08-16 |  | 126d |  |
| 85 | 2.7 | **2RW1 Initiate Pre-Acquisition Activities** |  | 5d? | 2021-08-03 | 2021-08-09 | 29 | 131d | 0d |
| 86 | 2.7.1 | - Prepare Right-of-Way Estimate |  | 5d | 2021-08-03 | 2021-08-09 |  | 131d |  |
| 87 | 2.7.2 | - Initiate PGI Field Work |  | 1d? | 2021-08-03 | 2021-08-03 |  | 135d |  |
| 88 | 2.7.3 | - Perform Title Searches |  | 1d? | 2021-08-03 | 2021-08-03 |  | 135d |  |
| 89 | 2.8 | **2UT1 Utility/Railroad Pre-Acquisition Activities** |  | 30d | 2021-09-23 | 2021-11-03 | 29, 34 | 0d |  |
| 90 | 2.8.1 | - Coordinate/Request Needed SUE |  | 10d | 2021-09-23 | 2021-10-06 |  | 0d |  |
| 91 | 2.8.2 | - Prepare Utility Estimate |  | 5d | 2021-09-23 | 2021-09-29 | 29 | 25d |  |
| 92 | 2.8.3 | - Prepare Railroad Estimates | inactive | 10d | 2021-09-23 | 2021-10-06 | 29 | 20d |  |
| 93 | 2.8.4 | - Develop a Utility Impact/Conflict Matrix |  | 10d | 2021-09-23 | 2021-10-06 |  | 20d |  |
| 94 | 2.8.5 | - Review SUE Data and Attend Internal Design Deconfliction Meeting |  | 10d | 2021-10-21 | 2021-11-03 | 71, 90, 66 | 0d |  |
| 95 | 2.9 | **2GT1 Complete the Soils and Geology Report** |  | 0d? | 2021-08-02 | 2021-08-02 | 29, 48 | 126d | 0d |
| 96 | 2.9.1 | - Conduct Site Exploration for Soils and Geology Report | inactive | 1d? | 2021-08-03 | 2021-08-03 |  | 125d |  |
| 97 | 2.9.2 | - Select the Appropriate Laboratory Testing Program | inactive | 5d | 2021-08-03 | 2021-08-09 |  | 121d |  |
| 98 | 2.9.3 | - Develop the Soils and Geology Report | inactive | 1d? | 2021-08-03 | 2021-08-03 |  | 125d |  |
| 99 | 2.9.4 | - Develop Associated Geotechnical Sheet (G-Sheets) | inactive | 1d? | 2021-08-03 | 2021-08-03 |  | 125d |  |
| 100 | 2.9.5 | - Develop Supporting Project Addenda | inactive | 1d? | 2021-08-03 | 2021-08-03 |  | 125d |  |
| 101 | 2.10 | **2GT2 Complete Soils/Foundation Reports** |  | 20d | 2021-08-03 | 2021-08-30 | 29, 48 | 130d | 57d |
| 102 | 2.10.1 | - Conduct Site Exploration for Structures | inactive | 1d? | 2021-08-03 | 2021-08-03 |  | 149d |  |
| 103 | 2.10.2 | - Complete and Submit Foundation Report for Retaining Wall(s) | inactive | 20d | 2021-08-03 | 2021-08-30 |  | 130d |  |
| 104 | 2.10.3 | - Complete and Submit Foundation Report for Noise Wall(s) | inactive | 20d | 2021-08-03 | 2021-08-30 |  | 130d |  |
| 105 | 2.10.4 | - Complete and Submit Standard Report for Signs, Lighting, Signals, ITS, and High-Mast Lighting |  | 20d | 2021-08-03 | 2021-08-30 |  | 130d |  |
| 106 | 2.10.5 | - Complete and Submit Foundation Report for Bridges | inactive | 20d | 2021-08-03 | 2021-08-30 |  | 130d |  |

Notes:
- 87: Duration will depend on number of acquisitions/relocations
- 88: Duration will depend on number of acquisitions/relocations
- 90: Coordinate with Line 70
- 93: Or use related line 69 under 2RD1

| ID | WBS | Task | Type | Duration | Start | Finish | Predecessors | Total slack | Free slack | Text1 |
| --- | --- | --- | --- | --- | --- | --- | --- | --- | --- | --- |
| 107 | 2.11 | **2ST1 Complete Hydraulic Design** |  | 0d? | 2021-08-02 | 2021-08-02 | 29, 53 | 136d | 67d |  |
| 108 | 2.11.1 | - Verify Proposed Grade and Estimate Hydraulic Structure Sizes | inactive | 1d? | 2021-08-03 | 2021-08-03 |  | 135d |  |  |
| 109 | 2.11.2 | - Develop Draft Hydraulic Layout | inactive | 1d? | 2021-08-03 | 2021-08-03 |  | 134d | 0d |  |
| 110 | 2.11.3 | - Hydraulically Model Proposed Conditions, Evaluate Proposals, and Select Appropriate Structure | inactive | 1d? | 2021-08-03 | 2021-08-03 |  | 134d | 0d |  |
| 111 | 2.11.4 | - Finalize Hydraulic Layout | inactive | 1d? | 2021-08-04 | 2021-08-04 | 109, 110 | 134d |  |  |
| 112 | 2.11.5 | - Finalize Hydraulic Design Information | inactive | 1d? | 2021-08-04 | 2021-08-04 | 109, 110 | 134d |  |  |
| 113 | 2.12 | **2ST2 Develop Preliminary Bridge Plans** |  | 0d? | 2021-08-02 | 2021-08-02 | 29, 23 | 136d | 67d |  |
| 114 | 2.12.1 | - Review Proposed Grade and Alignment for Non-Hydraulic Crossings | inactive | 1d? | 2021-08-03 | 2021-08-03 |  | 135d |  |  |
| 115 | 2.12.2 | - Develop Preliminary Bridge Layouts | inactive | 1d? | 2021-08-03 | 2021-08-03 |  | 135d |  |  |
| 116 | 2.12.3 | - Coordinate Geotechnical Analysis for Bridges | inactive | 5d | 2021-08-03 | 2021-08-09 |  | 131d |  |  |
| 117 | 2.13 | **2EN1 Complete Environmental Resource Effects/Impacts** |  | 1d? | 2021-08-03 | 2021-08-03 | 38, 29 | 158d | 0d |  |
| 118 | 2.13.1 | - Complete Necessary Resource Effect/Impact Evaluations (all other resources) |  | 1d? | 2021-08-03 | 2021-08-03 | 47 | 158d |  |  |
| 119 | 2.13.2 | - Finalize Historic Preservation Effects Study |  | 1d? | 2021-08-03 | 2021-08-03 | 39 | 158d |  |  |
| 120 | 2.13.3 | - Finalize Phase Two Archaeological Eligibility Study |  | 1d? | 2021-08-03 | 2021-08-03 | 40 | 158d |  |  |
| 121 | 2.13.4 | - Finalize Air Quality Impact Study |  | 1d? | 2021-08-03 | 2021-08-03 | 43 | 158d |  |  |
| 122 | 2.13.5 | - Finalize Noise Abatement Study |  | 1d? | 2021-08-03 | 2021-08-03 | 44 | 158d | 76d |  |
| 123 | 2.13.6 | - Finalize Ecology Environmental Boundaries Report |  | 1d? | 2021-08-03 | 2021-08-03 | 42 | 158d |  |  |
| 124 | 2.13.7 | - Confirm Multimodal Compliance Determination |  | 1d? | 2021-08-03 | 2021-08-03 |  | 158d |  |  |
| 125 | 2.14 | **2EN2 Complete Environmental Document** |  | 80d? | 2021-08-04 | 2021-11-23 | 29, 117 | 88d | 0d |  |
| 126 | 2.14.1 | - Confirm Approval of Project in the STIP |  | 1d | 2021-08-04 | 2021-08-04 |  | 167d |  |  |
| 127 | 2.14.2 | - Complete Environmental Resource Agency Coordination |  | 1d? | 2021-08-04 | 2021-08-04 |  | 167d |  |  |
| 128 | 2.14.3 | - Review/Finalize Purpose and Need Statement |  | 10d | 2021-08-04 | 2021-08-17 |  | 158d |  |  |
| 129 | 2.14.4 | - Complete Environmental Document |  | 1d? | 2021-08-04 | 2021-08-04 |  | 167d |  |  |
| 130 | 2.14.5 | - Receive FHWA NEPA Approval (as applicable) |  | 10d | 2021-08-04 | 2021-08-17 |  | 158d |  |  |
| 131 | 2.14.6 | - Functional Design Plans Review (if needed): Complete Environmental Document Re-Evaluation |  | 1d? | 2021-08-06 | 2021-08-06 | 78 | 165d |  | Yes |
| 132 | 2.14.7 | - Plan-in-Hand Review: Complete Environmental Document Re-Evaluation |  | 1d? | 2021-11-23 | 2021-11-23 | 157 | 88d |  | Yes |

Notes:
- 120: If needed
- 129: Includes sending FHWA Notice of Intent
- 131: This could be 3 weeks to 6 months depending on impacts/changes in design. This activity is optional depending on if the environmental document is complete at the time the plans are submitted for review.
- 132: This could be 3 weeks to 6 months depending on impacts/changes in design.

| ID | WBS | Task | Type | Duration | Start | Finish | Predecessors | Total slack | Free slack |
| --- | --- | --- | --- | --- | --- | --- | --- | --- | --- |
| 133 | 2.15 | **2EN3 Conduct Permit Assessment** |  | 0d | 2021-08-02 | 2021-08-02 | 29, 53, 42 | 134d | 0d |
| 134 | 2.15.1 | - Attend/Lead Permit Strategy Meeting (also see 2PM4) | inactive | 1d? | 2021-08-03 | 2021-08-03 |  | 133d |  |
| 135 | 2.15.2 | - Complete Permit Assessment, Redlined Plans, and Request for Permit Sketches | inactive | 1d? | 2021-08-03 | 2021-08-03 |  | 133d |  |
| 136 | 2.15.3 | - Lead Pre-application meeting with USACE and TDEC | inactive | 1d | 2021-08-03 | 2021-08-03 |  | 133d |  |
| 137 | 2.16 | **2EN4 Complete Mitigation Assessment and Initiate Mitigation Design** |  | 0d? | 2021-08-02 | 2021-08-02 | 29, 53, 42 | 136d | 67d |
| 138 | 2.16.1 | - Evaluate mitigation (Bank or In-Lieu fee) availability and permittee responsibilities | inactive | 1d? | 2021-08-03 | 2021-08-03 |  | 135d |  |
| 139 | 2.16.2 | - Complete Mitigation Assessment | inactive | 1d? | 2021-08-03 | 2021-08-03 |  | 135d |  |
| 140 | 2.16.3 | - Identify Need for Concurrent Project | inactive | 1d? | 2021-08-03 | 2021-08-03 |  | 135d |  |
| 141 | 2.16.4 | - Develop Preliminary Mitigation Plan (30% designed) | inactive | 1d? | 2021-08-03 | 2021-08-03 |  | -91d | 0d |
| 142 | 2.17 | **2TO1 Prepare ITS, Signals, and Lighting Sheets** |  | 1d? | 2021-08-12 | 2021-08-12 | 29, 55 | 128d | 59d |
| 143 | 2.17.1 | - Prepare TSMO/ITS Device Sheets |  | 1d? | 2021-08-12 | 2021-08-12 |  | 128d |  |
| 144 | 2.17.2 | - Prepare Signal Sheets |  | 1d? | 2021-08-12 | 2021-08-12 |  | 128d |  |
| 145 | 2.17.3 | - Prepare Lighting Sheets |  | 1d? | 2021-08-12 | 2021-08-12 |  | 128d |  |
| 146 | 2.17.4 | - Oversee Development of the Conceptual Traffic Control Strategies |  | 1d? | 2021-08-12 | 2021-08-12 |  | 128d |  |
| 147 | 2.18 | 2PM4 Conduct Permit Strategy Meeting(s) | milestone, inactive | 1d | 2021-08-03 | 2021-08-03 | 23, 29, 38 | 228d |  |
| 148 | 2.19 | **2PM5 Hold Functional Design Plans Field Review Meeting** |  | 10d | 2021-11-04 | 2021-11-17 | 69, 79, 83, 85, 89, 95, 107, 113, 133, 137, 142 | 69d | 0d |
| 149 | 2.19.1 | - Hold Meeting and Document/Distribute Minutes |  | 10d | 2021-11-04 | 2021-11-17 |  | 69d |  |
| 150 | 3 | **STAGE 3- PLAN-IN-HAND** |  | 161d? | 2021-08-03 | 2022-03-15 |  | 13d |  |
| 151 | 3.1 | **3RD1 Complete Plan-in-Hand Design** |  | 5d? | 2021-11-18 | 2021-11-24 | 148 | 69d |  |
| 152 | 3.1.1 | - Develop ROW Acquisition Exhibits |  | 1d? | 2021-11-18 | 2021-11-18 |  | 73d |  |
| 153 | 3.1.2 | - Develop Utility Coordination Plans |  | 1d? | 2021-11-18 | 2021-11-18 |  | 73d |  |
| 154 | 3.1.3 | - Develop Design and Sketches for Permit Applications | inactive | 1d? | 2021-11-18 | 2021-11-18 |  | -168d | 0d |
| 155 | 3.1.4 | - Finalize the TMP & Complete the Temporary Traffic Control Plans |  | 5d | 2021-11-18 | 2021-11-24 |  | 69d |  |
| 156 | 3.1.5 | - Complete Plan-in-Hand Plans |  | 1d | 2021-11-18 | 2021-11-18 |  | 73d | 0d |
| 157 | 3.1.6 | - Compile the Plan-in-Hand Plans for Field Review |  | 3d | 2021-11-18 | 2021-11-22 |  | 71d | 0d |

Notes:
- 152: This could begin in Stage 2. Consider advancing at risk if the project is under an accelerated schedule.
- 153: This could begin in Stage 2. Consider advancing at risk if the project is under an accelerated schedule.
- 156: Duration depends on size of the project/complexity of design, and can be run parallel with survey at risk.

| ID | WBS | Task | Type | Duration | Start | Finish | Predecessors | Total slack | Free slack |
| --- | --- | --- | --- | --- | --- | --- | --- | --- | --- |
| 158 | 3.2 | **3UT1 Perform Utility Coordination** |  | 84d | 2021-11-04 | 2022-03-01 | 65, 89 | 0d |  |
| 159 | 3.2.1 | - Process Consultant Requests |  | 5d | 2021-11-04 | 2021-11-10 |  | 79d |  |
| 160 | 3.2.2 | - Send Utility Coordination Plans |  | 5d | 2021-11-04 | 2021-11-10 |  | 39d | 0d |
| 161 | 3.2.3 | - Conduct Utility Plan Review Kickoff Meeting |  | 2d | 2021-11-04 | 2021-11-05 |  | 82d |  |
| 162 | 3.2.4 | - 60-Day Deconfliction Meeting |  | 40d | 2021-11-11 | 2022-01-05 | 160 | 39d |  |
| 163 | 3.2.5 | - Process Relocation Contract Requests |  | 5d | 2021-11-04 | 2021-11-10 |  | 79d |  |
| 164 | 3.2.6 | - Complete 120-day Utility Review and Submit Rainbows to Environmental |  | 84d | 2021-11-04 | 2022-03-01 |  | 0d |  |
| 165 | 3.2.7 | - Put Utilities to Work |  | 10d | 2021-11-04 | 2021-11-17 |  | 74d |  |
| 166 | 3.2.8 | - Submit Construction Drawings to Design |  | 5d | 2021-11-04 | 2021-11-10 |  | 79d |  |
| 167 | 3.3 | **3UT2 Perform Railroad Coordination** |  | 0d | 2021-11-18 | 2021-11-18 | 89, 156 | 73d |  |
| 168 | 3.3.1 | - Receive Railroad Plans and Estimates | inactive | 270d | 2021-11-19 | 2022-12-01 |  | -197d | 0d |
| 169 | 3.4 | **3UT3 Prepare and Submit Utility/Railroad Certification** |  | 10d | 2022-03-02 | 2022-03-15 | 158, 167 | 13d |  |
| 170 | 3.4.1 | - Receive and Process Utility Deposits |  | 10d | 2022-03-02 | 2022-03-15 |  | 13d |  |
| 171 | 3.4.2 | - Verify Utility Coordination is Complete |  | 5d | 2022-03-02 | 2022-03-08 |  | 18d |  |
| 172 | 3.4.3 | - Finalize Railroad Agreement(s) | inactive | 20d | 2022-03-02 | 2022-03-29 |  | 3d |  |
| 173 | 3.5 | **3EN1 Finalize Stream & Wetland Mitigation Design** |  | 0d? | 2021-11-17 | 2021-11-17 | 148, 137 | 74d |  |
| 174 | 3.5.1 | - Finalize Mitigation Plans | inactive | 1d? | 2021-11-18 | 2021-11-18 |  | 73d |  |
| 175 | 3.6 | **3EN2 Complete Environmental Permit Applications and Obtain Permits** |  | 40d | 2021-08-03 | 2021-09-27 | 133 | 134d |  |
| 176 | 3.6.1 | - Complete Stormwater Permit Application |  | 10d | 2021-08-03 | 2021-08-16 |  | 134d | 0d |
| 177 | 3.6.2 | - Complete Aquatic Permit Applications | inactive | 40d | 2021-11-19 | 2022-01-13 | 141, 154, 133 | -168d | 0d |
| 178 | 3.6.3 | **- Obtain Aquatic Resource Permits** | inactive | 224d | 2022-01-14 | 2022-11-23 |  | -168d | 0d |
| 179 | 3.6.3.1 | - 45 day Agency review | inactive | 32d | 2022-01-14 | 2022-02-28 | 177 | -168d | 0d |
| 180 | 3.6.3.2 | - 30 days TDOT response to RFI/RAI and incorporate utilities (if needed) | inactive | 20d | 2022-03-01 | 2022-03-28 | 179 | -168d | 0d |
| 181 | 3.6.3.3 | - 30 days Agency Review | inactive | 20d | 2022-03-29 | 2022-04-25 | 180 | -168d | 0d |
| 182 | 3.6.3.4 | - 30 days TDOT response to RFI/RAI | inactive | 20d | 2022-04-26 | 2022-05-23 | 181 | -168d | 0d |
| 183 | 3.6.3.5 | - 45 days for drafting permit | inactive | 32d | 2022-05-24 | 2022-07-06 | 182, 125 | -168d | 0d |
| 184 | 3.6.3.6 | - 30 day public notice | inactive | 20d | 2022-07-07 | 2022-08-03 | 183 | -168d | 0d |
| 185 | 3.6.3.7 | - 90 day request for hearing (if needed) | inactive | 60d | 2022-08-04 | 2022-10-26 | 184 | -168d | 0d |
| 186 | 3.6.3.8 | - USACE to send to EPA for final review | inactive | 10d | 2022-10-27 | 2022-11-09 | 185 | -168d | 0d |
| 187 | 3.6.3.9 | - USACE issues the permit | inactive | 10d | 2022-11-10 | 2022-11-23 | 186 | -168d | 0d |
| 188 | 3.6.4 | - Obtain NPDES Coverage |  | 30d | 2021-08-17 | 2021-09-27 | 176 | 134d |  |

Notes:
- 167: Tied currently to Plan-in-Hand Plans, but could tie to Functional Design Plans if coordinated with Railroad

| ID | WBS | Task | Type | Duration | Start | Finish | Predecessors | Total slack | Free slack |
| --- | --- | --- | --- | --- | --- | --- | --- | --- | --- |
| 189 | 3.7 | **3ST1 Complete Structural Design** |  | 0d? | 2021-11-17 | 2021-11-17 | 148, 65, 101 | 74d |  |
| 190 | 3.7.1 | - Complete Retaining/Noise Wall Sheets | inactive | 1d? | 2021-11-18 | 2021-11-18 | 122 | 73d |  |
| 191 | 3.7.2 | - Complete Design and Detail Bridge Plans and Estimate | inactive | 1d? | 2021-11-18 | 2021-11-18 |  | 73d |  |
| 192 | 3.8 | **3RW1 Complete Appraisal and Initiate Acquisition** |  | 30d? | 2021-08-10 | 2021-09-20 | 85, 29 | 134d | 46d |
| 193 | 3.8.1 | - Produce Preliminary Group Inspection (PGI) Report |  | 1d? | 2021-08-10 | 2021-08-10 |  | 163d |  |
| 194 | 3.8.2 | - Initiate Private Property Owner Utility Adjustment |  | 1d? | 2021-08-10 | 2021-08-10 |  | 163d |  |
| 195 | 3.8.3 | - Employ Fee Appraiser |  | 30d | 2021-08-10 | 2021-09-20 |  | 134d |  |
| 196 | 3.8.4 | - Appraise Property |  | 1d? | 2021-08-10 | 2021-08-10 |  | 163d |  |
| 197 | 3.8.5 | - Review Appraisals |  | 1d? | 2021-08-10 | 2021-08-10 |  | 163d |  |
| 198 | 3.9 | **3RW2 Execute ROW Proposal** |  | 0d? | 2021-11-17 | 2021-11-17 | 148 | 97d |  |
| 199 | 3.9.1 | - Prepare/Submit ROW Proposal | inactive | 1d? | 2021-11-18 | 2021-11-18 |  | 96d |  |
| 200 | 3.9.2 | - Receive ROW Proposal and Distribute for Execution | inactive | 1d? | 2021-11-18 | 2021-11-18 |  | 96d |  |
| 201 | 3.10 | **3RW3 Prepare and Submit ROW Certification** |  | 5d? | 2021-11-24 | 2021-11-30 | 125, 192 | 88d |  |
| 202 | 3.10.1 | - Perform/Finish Acquiring Property |  | 1d? | 2021-11-24 | 2021-11-24 |  | 92d |  |
| 203 | 3.10.2 | - Perform/Finish ROW Relocation |  | 1d? | 2021-11-24 | 2021-11-24 |  | 92d |  |
| 204 | 3.10.3 | - Review ROW Acquisition Process, Verify/Update Schedule, and Issue ROW Certification |  | 5d | 2021-11-24 | 2021-11-30 |  | 88d |  |
| 205 | 3.11 | **3TO1 Complete Signal, Lighting, and TSMO/ITS Device Design** |  | 1d? | 2021-11-18 | 2021-11-18 | 148, 101, 65 | 73d |  |
| 206 | 3.11.1 | - Complete Signal Design |  | 1d? | 2021-11-18 | 2021-11-18 |  | 73d |  |
| 207 | 3.11.2 | - Complete Lighting Design |  | 1d? | 2021-11-18 | 2021-11-18 |  | 73d |  |
| 208 | 3.11.3 | - Complete TSMO/ITS Device Design |  | 1d? | 2021-11-18 | 2021-11-18 |  | 73d |  |
| 209 | 3.11.4 | - Review the TMP for Compliance |  | 1d? | 2021-11-18 | 2021-11-18 |  | 73d |  |
| 210 | 3.12 | **3PM2 Hold Plan-in-Hand Field Review Meeting** |  | 10d | 2022-03-02 | 2022-03-15 | 151, 158, 167, 173, 189, 205 | 0d |  |
| 211 | 3.12.1 | - Hold Meeting and Document/Distribute Minutes |  | 10d | 2022-03-02 | 2022-03-15 |  | 0d |  |
| 212 | 4 | **STAGE 4- PS&E** |  | 13d? | 2022-03-15 | 2022-04-01 |  | 0d |  |
| 213 | 4.1 | **4RD1 Finalize Construction Documents** |  | 3d? | 2022-03-16 | 2022-03-18 | 210 | 0d |  |
| 214 | 4.1.1 | - Finalize the Roadway Plans for the PS&E Review Meeting |  | 1d? | 2022-03-16 | 2022-03-16 |  | 2d |  |
| 215 | 4.1.2 | - Compile the Final Construction Documents |  | 3d | 2022-03-16 | 2022-03-18 |  | 0d |  |

Notes:
- 196: Duration will depend on number of acquisitions/relocations
- 197: Duration will depend on number of acquisitions/relocations
- 202: Duration will depend on number of acquisitions/relocations
- 203: Duration will depend on number of acquisitions/relocations

| ID | WBS | Task | Type | Duration | Start | Finish | Predecessors | Total slack |
| --- | --- | --- | --- | --- | --- | --- | --- | --- |
| 216 | 4.2 | **4GT1 Finalize Geotech Plans** |  | 1d? | 2022-03-16 | 2022-03-16 | 210, 95, 101 | 2d |
| 217 | 4.2.1 | - Finalize Geotechnical Design Documents |  | 1d? | 2022-03-16 | 2022-03-16 |  | 2d |
| 218 | 4.2.2 | - Finalize Geotechnical Special Provisions for Letting |  | 1d? | 2022-03-16 | 2022-03-16 |  | 2d |
| 219 | 4.3 | **4ST1 Finalize Structural Plans** |  | 0d? | 2022-03-15 | 2022-03-15 | 210 | 3d |
| 220 | 4.3.1 | - Finalize Retaining/Noise Wall Plans | inactive | 1d? | 2022-03-16 | 2022-03-16 |  | 2d |
| 221 | 4.3.2 | - Finalize Bridge Plans | inactive | 1d? | 2022-03-16 | 2022-03-16 |  | 2d |
| 222 | 4.4 | **4TO1 Finalize Signal, Lighting, and TSMO/ITS Plans** |  | 1d? | 2022-03-16 | 2022-03-16 | 210 | 2d |
| 223 | 4.4.1 | - Finalize Signals, Lighting, and TSMO/ITS Design Documents |  | 1d? | 2022-03-16 | 2022-03-16 |  | 2d |
| 224 | 4.4.2 | - Finalize ITS Special Provisions for Letting |  | 1d? | 2022-03-16 | 2022-03-16 |  | 2d |
| 225 | 4.5 | **4PM2 Hold PS&E Review Meeting** |  | 10d | 2022-03-21 | 2022-04-01 | 213, 216, 219, 222 | 0d |
| 226 | 4.5.1 | - Hold Meeting and Document/Distribute Minutes |  | 10d | 2022-03-21 | 2022-04-01 |  | 0d |
| 227 | 5 | Construction Document Turn-in | milestone | 5d | 2022-04-04 | 2022-04-08 | 169, 175, 225, 198, 201, 125 | 0d |
| 228 | 6 | Project Letting | milestone | 50d | 2022-04-11 | 2022-06-17 | 227 | 0d |
